# 3GPP_Work Plan

Schedule from MS Project, 2000-01-03 to 2004-12-17, A marks actual dates.

## Calendars

- Standard: Mon-Fri 08:00-12:00, 13:00-17:00; Sat-Sun off.

## Resources

| Resource |
| --- |
| NP |
| N1 |
| N2 |
| N3 |
| N4 |
| N5 |
| TP |
| T1 |
| T2 |
| T3 |
| RP |
| R1 |
| R2 |
| R3 |
| R4 |
| SP |
| S1 |
| S2 |
| S3 |
| S4 |
| S5 |
| PCG |
| GP |
| No |
| CN4 |
| ? |
| WG G2 |
| G2 |
| G1 |
| G4 |
| G3 |
| All |
| Generic |
| MLST |
| G5 |
| S3, G2 |
| WG T2 |
| GP,G1 |
| G4,G5 |
| OMA |

## Schedule

| ID | WBS | Task | Duration | Start | Finish | Complete | Remaining | Baseline start | Baseline finish | Baseline duration | Total slack | Constraint | Resources | Work | Actual work | Text6 | Text9 | Text1 | Text4 | Text7 | Text8 | Text2 | Text5 |
| --- | --- | --- | --- | --- | --- | --- | --- | --- | --- | --- | --- | --- | --- | --- | --- | --- | --- | --- | --- | --- | --- | --- | --- |
| 1 | 1 | Work Plan Rel-6 and after- VERSION 2003 July 25th | 1d | 2000-01-03 | 2000-01-03 |  |  | 2000-01-03 | 2000-01-03 | 1d | 1294d |  |  |  |  | Rel | 2044 |  |  |  |  |  |  |
| 2 | 2 | "CTRL + a" to display all the 3GPP fields | 1d | 2000-01-03 | 2000-01-03 |  |  | 2000-01-03 | 2000-01-03 | 1d | 1294d |  |  |  |  |  | 1462 |  |  |  |  |  |  |
| 3 | 3 | Content of Rel-6 and after. Not frozen. | 1d | 2000-01-03 | 2000-01-03 |  |  | 2000-01-03 | 2000-01-03 | 1d | 1294d |  |  |  |  | Rel | 2058 |  |  |  |  |  |  |
| 5 | 6 | Evolutions of the transport in the UTRAN | 218d | 2003-03-03 | 2003-12-31 |  |  | 2003-03-03 | 2003-12-31 | 218d | 252d | start no earlier than 2003-03-01 | RP | 1744h |  | NA |  | ETRAN | Francois Courau | TSG | Joern |  |  |
| 6 | 8 | **Improvements of Radio Interface** | 940d? | 2000-08-14 A | 2004-03-19 | 46% | 508.85d? | 2000-08-14 | 2004-03-19 | 940d? | 195d |  | RP | 63576h | 31772h | Rel-6 |  | RInImp |  | TSG | Tsukasa |  |  |
| 7 | 8.6 | Improving Receiver Performance Requirements for the FDD UE | 401d | 2002-03-08 A | 2003-09-19 | 70% | 120.3d | 2002-03-08 | 2003-09-19 | 401d | 325d | finish no earlier than 2003-09-19 | R4 | 3208h | 2245.6h | Rel-6 |  | RInImp-UERecPerf | Shimon Moshavi, Intel | TSG |  |  |  |
| 8 | 8.1 | Improvement of inter-frequency and inter-system measurement | 705d | 2001-01-01 A | 2003-09-12 | 10% | 634.5d | 2001-01-01 | 2003-09-12 | 705d | 330d | finish no earlier than 2003-09-12 | R1 | 5640h | 564h | Rel-6 | 1470 | RInImp-IfIsM | Nokia (Antti Toskala) | TSG |  | BaAS |  |
| 9 | 8.2 | **Base station classification** | 603d | 2000-08-14 A | 2002-12-04 A | 100% |  | 2000-08-14 | 2002-12-04 | 603d |  |  | R4 | 9648h | 9648h | Rel-6 |  | RInImp-BSClass |  | TSG |  |  |  |
| 10 | 8.2.1 | FDD Base station classification | 603d | 2000-08-14 A | 2002-12-04 A | 100% |  | 2000-08-14 | 2002-12-04 | 603d |  | finish no earlier than 2002-12-04 | R4 | 4824h | 4824h | Rel-6 | 1476 | RInImp-BSClass-FDD | A. Toskala, Nokia | TSG |  | BaAs |  |
| 11 | 5.4 | UMTS-850 | 331d? | 2002-12-06 A | 2004-03-12 | 40% | 198.6d? | 2002-12-06 | 2004-03-12 | 331d? | 200d | finish no earlier than 2004-03-12 | R4 | 2648h | 1059.2h | Rel-6 |  | RInImp-UMTS850 | Don Zelmer, Cingular | TSG |  |  | don.zelmer@cingular.com |
| 12 | 5.5 | DS-CDMA introduction in the 800 MHz band | 136d? | 2003-03-14 A | 2003-09-19 | 25% | 102d? | 2003-03-14 | 2003-09-19 | 136d? | 325d | finish no earlier than 2003-09-19 | R4 | 1088h | 272h | Rel-6 |  | RInImp-UMTS800 | Takehiro Nakamura, NTT DoCoMo | TSG |  |  | takehiro@wsp.yrp.nttdocomo.co.jp |
| 13 | 5.6 | UMTS 1.7/2.1 GHz | 196d? | 2003-03-14 A | 2003-12-12 | 10% | 176.4d? | 2003-03-14 | 2003-12-12 | 196d? | 265d | finish no earlier than 2003-12-12 | R4 | 1568h | 156.8h | Rel-6 |  | RInImp-UMTS1721 | Jussi Numminen, Nokia | TSG |  |  | jussi.numminen@NOKIA.COM |
| 14 | 8.7 | FS for the viable deployment of UTRA in additional and diverse spectrum arrangements | 326d | 2002-03-08 A | 2003-06-06 A | 100% |  | 2002-03-08 | 2003-06-06 | 326d |  | finish no earlier than 2003-06-06 | R4 | 2608h | 2608h | Rel-6 |  | RInImp-UMTSBands | Thomas Unshelm, Ericsson | TSG | Cesar |  | Thomas.Unshelm@era.ericsson.se |
| 15 | 8.8 | FS on UE antenna efficiency test methods performance requirements (2) | 131d | 2002-03-08 A | 2002-09-06 A | 100% |  | 2002-03-08 | 2002-09-06 | 131d |  | finish no earlier than 2002-09-06 | R4 | 1048h | 1048h | Rel-6 |  | RInImp-UEAnTM2 | Alf Ahlström, Allgon | TSG |  |  |  |
| 16 | 8.10 | FS on Radio link performance enhancements | 940d | 2000-08-14 A | 2004-03-19 | 40% | 564d | 2000-08-14 | 2004-03-19 | 940d | 195d | finish no earlier than 2004-03-19 | R1 | 7520h | 3008h | Rel-6 | 1506 | RInImp-Rlperf | Antti Toskala, Nokia Networks | TSG |  |  |  |
| 17 | 8.11 | FS on UTRA WideBand Distribution Systems | 790d | 2001-03-12 A | 2004-03-19 | 40% | 474d | 2001-03-12 | 2004-03-19 | 790d | 195d | finish no earlier than 2004-03-19 | R4 | 6320h | 2528h | Rel-6 |  | RInImp-WDS | Andrea Casini, Tekmar Sistemi | TSG |  |  |  |
| 18 | 8.12 | FS on Improvement of inter-frequency and inter-system measurements for 1.28 Mcps TDD | 461d | 2001-12-14 A | 2003-09-19 | 55% | 207.45d | 2001-12-14 | 2003-09-19 | 461d | 325d | finish no earlier than 2003-09-19 | R1 | 3688h | 2028.4h | Rel-6 |  | RInImp-IfIsMLCR | Li Xiao Qiang, SAMSUNG | TSG |  |  |  |
| 19 | 8.13 | FS for the analysis of OFDM for UTRAN enhancements | 390d | 2002-06-10 A | 2003-12-05 | 35% | 253.5d | 2002-06-10 | 2003-12-05 | 390d | 270d | finish no earlier than 2003-12-05 | R1 | 3120h | 1092h | Rel-6 |  | RInImp-FSOFDM | Sarah Boumendil, Nortel | TSG |  |  |  |
| 20 | 8.14 | FS on Uplink Enhancements for Dedicated Transport Channels | 326d | 2002-09-06 A | 2003-12-05 | 40% | 195.6d | 2002-09-06 | 2003-12-05 | 326d | 270d | finish no earlier than 2003-12-05 | R1 | 2608h | 1043.2h | Rel-6 |  | RInImp-FSUpDTrCh | Karri Ranta-aho, Nokia | TSG |  |  |  |
| 21 | 8.15 | FS on Analysis on Higher Chip Rates for UTRA TDD evolutions | 326d | 2002-09-06 A | 2003-12-05 | 35% | 211.9d | 2002-09-06 | 2003-12-05 | 326d | 270d | finish no earlier than 2003-12-05 | R1 | 2608h | 912.8h | Rel-6 |  | RInImp-FSVHCRTDD | Tim Wilkinson, IPWireless | TSG |  |  |  |
| 22 | 5.15 | FS on Low Output Powers for general purpose FDD BSs | 136d? | 2003-06-13 A | 2003-12-19 | 10% | 122.4d? | 2003-06-13 | 2003-12-19 | 136d? | 260d | finish no earlier than 2003-12-19 | R4 | 1088h | 108.8h | Rel-6 |  | RInImp-FSLOP | Jose Alberto Martin, Telefonica | TSG |  |  | martin_ja4@tsm.es |
| 23 | 5.16 | FS on Uplink enhancements for UTRA TDD | 206d? | 2003-06-06 | 2004-03-19 |  |  | 2003-06-06 | 2004-03-19 | 206d? | 195d | finish no earlier than 2004-03-19 | R1 | 1648h |  | Rel-6 |  | RInImp-FSUpEnhTDD | TBD | TSG |  |  | TBD |
| 24 | 8.5 | **Multiple Input Multiple Output antennas (MIMO)** | 461d? | 2003-03-14 A | 2004-12-17 | 13% | 399.99d? | 2003-03-14 | 2004-12-17 | 461d? | 0d |  | R1 | 10120h | 2950.4h | Rel-6 | 2468 | RInImp-MIMO | Howard Huang, Lucent | TSG |  |  | hchuang@lucent.com |
| 25 | 6.1 | Multiple Input Multiple Output antennas - Physical layer | 266d? | 2003-03-14 A | 2004-03-19 | 35% | 172.9d? | 2003-03-14 | 2004-03-19 | 266d? | 195d | finish no earlier than 2004-03-19 | R1 | 2128h | 744.8h | Rel-6 |  | RInImp-MIMO-Phys | Howard Huang, Lucent | TSG |  |  | hchuang@lucent.com |
| 26 | 6.2 | Multiple Input Multiple Output antennas - Layer 2,3 aspects | 136d? | 2003-09-12 | 2004-03-19 |  |  | 2003-09-12 | 2004-03-19 | 136d? | 195d | finish no earlier than 2004-03-19 | R2 | 1088h |  | Rel-6 |  | RInImp-MIMO-L23 | Howard Huang, Lucent | TSG |  |  | hchuang@lucent.com |
| 27 | 6.3 | Multiple Input Multiple Output antennas - Iub/Iur Protocol Aspects | 136d? | 2003-03-14 | 2003-09-19 |  |  | 2003-03-14 | 2003-09-19 | 136d? | 325d | finish no earlier than 2003-09-19 | R3 | 1088h |  | Rel-6 |  | RInImp-MIMO-IurIub | Howard Huang, Lucent | TSG |  |  | hchuang@lucent.com |
| 28 | 6.4 | Multiple Input Multiple Output antennas - RF Radio Transmission/Reception, System Performance Requirements and Conformance Testing | 266d? | 2003-12-12 A | 2004-12-17 | 5% | 252.7d? | 2003-12-12 | 2004-12-17 | 266d? | 0d | finish no earlier than 2004-12-17 | R4 | 2128h | 106.4h | Rel-6 |  | RInImp-MIMO-RF | Howard Huang, Lucent | TSG |  |  | hchuang@lucent.com |

Notes:
- 5: To be deleted at TSG#18 if no input. Might be deleted
- 8: RP-020389
- 15: The RInImp-UEAnTM FS was re-opened at TSG RAN#15 upon request from WG4
- 16: RP-020358
- 18: RP-020374

| ID | WBS | Task | Duration | Start | Finish | Complete | Remaining | Baseline start | Baseline finish | Baseline duration | Total slack | Constraint | Resources | Work | Actual work | Text1 | Text6 | Text7 | Text8 | Text4 | Text2 | Text9 | Text5 | Text3 |
| --- | --- | --- | --- | --- | --- | --- | --- | --- | --- | --- | --- | --- | --- | --- | --- | --- | --- | --- | --- | --- | --- | --- | --- | --- |
| 29 | 9 | **RAN improvements** | 591d? | 2001-12-14 A | 2004-03-19 | 38% | 364.31d? | 2001-12-14 | 2004-03-19 | 591d? | 195d |  | RP | 24824h | 9415.96h | RANimp | Rel-6 | TSG | Cesar |  |  |  |  |  |
| 30 | 9.1 | Beamforming Enhancements | 461d | 2001-12-14 A | 2003-09-19 | 80% | 92.2d | 2001-12-14 | 2003-09-19 | 461d | 325d | finish no earlier than 2003-09-19 | R1 | 3688h | 2950.4h | RANimp-BFE | Rel-6 | TSG |  | Jussi Kähtävä, Nokia |  |  |  |  |
| 31 | 9.2 | **RAB support enhancement** | 266d? | 2003-03-14 A | 2004-03-19 | 5% | 252.7d? | 2003-03-14 | 2004-03-19 | 266d? | 195d |  | R2 | 4256h | 212.8h | RANimp-RABSE | Rel-6 | TSG |  | M. Israelsson, A. Krishnarajah, Ericsson | BaAS | 624 |  |  |
| 32 | 7.2.1 | Iu enhancements for IMS support in RAN | 266d? | 2003-03-14 A | 2004-03-19 | 5% | 252.7d? | 2003-03-14 | 2004-03-19 | 266d? | 195d | finish no earlier than 2004-03-19 | R3 | 2128h | 106.4h | RANimp-RABSE-IuEnhIMS | Rel-6 | TSG |  | Phillipe Godin, Nortel |  |  |  |  |
| 33 | 9.3 | Improvement of RRM across RNS and RNS/BSS | 445d | 2002-03-25 A | 2003-12-05 | 35% | 289.25d | 2002-03-25 | 2003-12-05 | 445d | 270d | finish no earlier than 2003-12-05 | R3 | 3560h | 1246h | RANimp-RRM1 | Rel-6 | TSG |  | Sami Kekki, Nokia |  |  | sami.kekki@nokia.com |  |
| 34 | 9.4 | FS on the evolution of the UTRAN architecture | 335d | 2002-09-09 A | 2003-12-19 | 20% | 268d | 2002-09-09 | 2003-12-19 | 335d | 260d | finish no earlier than 2003-12-19 | R3 | 2680h | 536h | RANimp-FSEvo | Rel-6 | TSG |  | Woonhee Hwang, Nokia |  |  |  |  |
| 35 | 7.5 | **Rel6 RRM optimization for Iur and Iub** | 206d? | 2002-12-06 A | 2003-09-19 | 75% | 51.5d? | 2002-12-06 | 2003-09-19 | 206d? | 325d |  | R3 | 3296h | 2472h | RANimp-RRMopt | Rel-6 | TSG |  | Gert-Jan van Lieshout, Ericsson | BaAS |  |  |  |
| 36 | 7.5.1 | FS of the improved access to UE measurement data for CRNC to support TDD RRM | 206d? | 2002-12-06 A | 2003-09-19 | 75% | 51.5d? | 2002-12-06 | 2003-09-19 | 206d? | 325d | finish no earlier than 2003-09-19 | R3 | 1648h | 1236h | RANimp-RRMopt-FSTDDRRM | Rel-6 | TSG |  | Jim Miller, Interdigital |  |  |  |  |
| 37 | 7.6 | Remote Control of Electrical Tilting Antennas | 191d? | 2003-03-14 A | 2003-12-05 | 5% | 181.45d? | 2003-03-14 | 2003-12-05 | 191d? | 270d | finish no earlier than 2003-12-05 | R3 | 1528h | 76.4h | RANimp-TiltAnt | Rel-6 | TSG |  | Andreas Hauser, Vodafone |  |  |  |  |
| 38 | 7.7 | Network Assisted Cell Change (NACC) from UTRAN to GERAN - network-side aspects | 136d? | 2003-06-13 A | 2003-12-19 | 10% | 122.4d? | 2003-06-13 | 2003-12-19 | 136d? | 260d | finish no earlier than 2003-12-19 | R3 | 1088h | 108.8h | RANimp-NACC | Rel-6 | TSG |  | Brendan McWilliams, Vodafone |  |  | Brendan.McWilliams@gb.vodafone.co.uk |  |
| 39 | 8 | **PS domain and IMS impacts for supporting IMS Emergency calls** | 870d? | 2000-08-14 A | 2003-12-12 | 34% | 577.75d? | 2000-08-14 | 2003-12-12 | 870d? | 265d |  | S2 | 32768h | 9673.15h | EMC1 | Rel-6 | TSG |  | Miikka Poikselka, Nokia |  |  |  |  |
| 40 | 10.1.1 | Service Requirements for IP-based emergency calls | 725d | 2000-09-18 A | 2003-06-27 | 90% | 72.5d | 2000-09-18 | 2003-06-27 | 725d | 385d | finish no earlier than 2003-06-27 | S1 | 5800h | 5220h |  | Rel-6 |  |  |  | CCaR | 1314 |  | 22.976 |
| 41 | 8.2 | Stage 2 | 147d? | 2003-02-26 A | 2003-09-18 | 36% | 94.08d? | 2003-02-26 | 2003-09-18 | 147d? | 326d | finish no earlier than 2003-09-18 | S2 | 1176h | 423.36h |  | Rel-6 | TSG |  | Miikka Poikselka, Nokia |  |  |  |  |
| 42 | 10.1 | **Emergency Call Enhancements for IP& PS Based Calls – stage 3** | 870d | 2000-08-14 A | 2003-12-12 | 9% | 789.59d | 2000-08-14 | 2003-12-12 | 870d | 265d |  | N1 | 19032h | 1758.94h |  | Rel-6 |  |  | Mr Atle Monrad, Ericsson | CCaR | 1653 | Atle.Monrad@eto.ericsson.se |  |
| 43 | 10.1.2 | SIP emergency calls and packet emergency calls signalling flows | 824d | 2000-10-17 A | 2003-12-12 | 19% | 667.44d | 2000-10-17 | 2003-12-12 | 824d | 265d | finish no earlier than 2003-12-12 | N1 | 6592h | 1252.48h |  | Rel-6 |  |  | Mr Atle Monrad, Ericsson | CCaR | 1315 | Atle.Monrad@eto.ericsson.se | TS 24.228 |
| 44 | 10.1.5 | Stage 3 for emergency calls and packet emergency calls in general | 870d | 2000-08-14 | 2003-12-12 |  |  | 2000-08-14 | 2003-12-12 | 870d | 265d | finish no earlier than 2003-12-12 | N1 | 6960h |  |  | Rel-6 |  |  | Mr Atle Monrad, Ericsson | CCaR | 1646 | Atle.Monrad@eto.ericsson.se | TS 24.229 |
| 45 | 12 | **Location Services enhancements 2** | 930d? | 2000-08-28 A | 2004-03-19 | 52% | 449.42d? | 2000-08-28 | 2004-03-19 | 930d? | 195d |  | S2 | 71464h | 37248.6h | LCS2 | Rel-6 | TSG | Sang-Ui |  |  |  |  |  |
| 46 | 12.1 | **Improvement on Le interface** | 397d? | 2002-06-17 A | 2003-12-23 | 60% | 157.55d? | 2002-06-17 | 2003-12-23 | 397d? | 258d |  | S2 | 6776h | 4086.98h |  | Rel-6 | TSG |  |  |  |  |  |  |
| 47 | 9.1.1 | Stage 2 | 331d? | 2002-06-17 A | 2003-09-22 | 82% | 59.58d? | 2002-06-17 | 2003-09-22 | 331d? | 324d | start no earlier than 2002-06-17 | S2 | 2648h | 2171.36h |  | Rel-6 |  |  |  |  |  |  |  |
| 48 | 9.1.2 | Stage 3 in OMA - it impacts Mobile Location Protocol (MLP) | 119d? | 2003-07-10 | 2003-12-23 |  |  | 2003-07-10 | 2003-12-23 | 119d? | 258d | finish no earlier than 2003-12-23 | OMA | 952h |  |  | Rel-6 |  |  |  |  |  |  |  |
| 49 | 12.2 | **Enhanced support for anonymity and user privacy** | 382d? | 2002-07-08 A | 2003-12-23 | 68% | 121.55d? | 2002-07-08 | 2003-12-23 | 382d? | 258d |  | S2 | 6048h | 4072.03h |  | Rel-6 | TSG |  |  |  |  |  |  |
| 50 | 9.2.1 | Stage 2 | 255d? | 2002-07-08 A | 2003-06-27 A | 100% |  | 2002-07-08 | 2003-06-27 | 255d? |  | finish no earlier than 2003-06-27 | S2 | 2040h | 2040h |  | Rel-6 |  |  |  |  |  |  |  |
| 51 | 9.2.2 | Stage 3 in OMA (it impacts MLP and RLP) | 119d? | 2003-07-10 | 2003-12-23 |  |  | 2003-07-10 | 2003-12-23 | 119d? | 258d | finish no earlier than 2003-12-23 | OMA | 952h |  |  | Rel-6 |  |  |  |  |  |  |  |
| 52 | 12.3 | **Enhanced inter-GMLC interface** | 320d? | 2002-06-24 A | 2003-09-12 | 76% | 75.82d? | 2002-06-24 | 2003-09-12 | 320d? | 330d |  | S2 | 7240h | 5524.68h |  | Rel-6 | TSG |  |  |  |  |  |  |
| 53 | 9.3.1 | Stage 2 | 315d? | 2002-06-24 A | 2003-09-05 | 86% | 44.1d? | 2002-06-24 | 2003-09-05 | 315d? | 335d | finish no earlier than 2003-09-05 | S2 | 2520h | 2167.2h |  | Rel-6 |  |  |  |  |  |  |  |
| 54 | 9.3.2 | Stage 3 in OMA (definition of RLP and PCP) | 270d? | 2002-09-02 A | 2003-09-12 | 65% | 94.5d? | 2002-09-02 | 2003-09-12 | 270d? | 330d | finish no earlier than 2003-09-12 | OMA | 2160h | 1404h |  | Rel-6 |  |  |  |  |  |  |  |

Notes:
- 30: RP-020357
- 31: This is a building block without particular end date

| ID | WBS | Task | Duration | Start | Finish | Complete | Remaining | Baseline start | Baseline finish | Baseline duration | Total slack | Constraint | Resources | Work | Actual work | Text6 | Text7 | Text1 | Text4 | Text9 | Text5 | Text8 | Text2 | Text3 |
| --- | --- | --- | --- | --- | --- | --- | --- | --- | --- | --- | --- | --- | --- | --- | --- | --- | --- | --- | --- | --- | --- | --- | --- | --- |
| 55 | 12.4 | **Location Services support for IMS public identities** | 340d? | 2002-09-02 A | 2003-12-19 | 39% | 208.75d? | 2002-09-02 | 2003-12-19 | 340d? | 260d |  | S2 | 6160h | 2377.98h | Rel-6 | TSG |  |  |  |  |  |  |  |
| 56 | 9.4.1 | Stage 2 | 215d? | 2003-02-24 A | 2003-12-19 | 19% | 174.15d? | 2003-02-24 | 2003-12-19 | 215d? | 260d | finish no earlier than 2003-12-19 | S2 | 1720h | 326.8h | Rel-6 |  |  |  |  |  |  |  |  |
| 57 | 9.4.2 | Stage 3 in OMA (impacts MLP, RLP and PCP) | 340d? | 2002-09-02 A | 2003-12-19 | 51% | 166.6d? | 2002-09-02 | 2003-12-19 | 340d? | 260d | finish no earlier than 2003-12-19 | OMA | 2720h | 1387.2h | Rel-6 |  |  |  |  |  |  |  |  |
| 58 | 12.5 | **New area event for location service triggering reports** | 406d? | 2002-06-03 A | 2003-12-22 | 55% | 184.4d? | 2002-06-03 | 2003-12-22 | 406d? | 259d |  | S2 | 7352h | 4472.03h | Rel-6 | TSG |  |  |  |  |  |  |  |
| 59 | 9.5.1 | Stage 2 | 280d? | 2002-06-03 A | 2003-06-27 A | 100% |  | 2002-06-03 | 2003-06-27 | 280d? |  | finish no earlier than 2003-06-27 | S2 | 2240h | 2240h | Rel-6 |  |  |  |  |  |  |  |  |
| 60 | 9.5.2 | Stage 3 for UE-CN signalling | 118d? | 2003-07-10 | 2003-12-22 |  |  | 2003-07-10 | 2003-12-22 | 118d? | 259d | finish no earlier than 2003-12-22 | N4 | 944h |  | Rel-6 |  |  |  |  |  |  |  |  |
| 61 | 9.5.3 | Stage 3 in OMA (impacts MLP, RLP and PCP) | 115d? | 2003-07-14 | 2003-12-19 |  |  | 2003-07-14 | 2003-12-19 | 115d? | 260d | finish no earlier than 2003-12-19 | OMA | 920h |  | Rel-6 |  |  |  |  |  |  |  |  |
| 62 | 12.6 | **FS on applicability of GALILEO for LCS** | 445d? | 2002-07-08 A | 2004-03-19 | 45% | 246.97d? | 2002-07-08 | 2004-03-19 | 445d? | 195d |  | S2 | 8360h | 3136h | Rel-6 |  |  |  |  |  |  |  |  |
| 63 | 9.6.1 | TR on Stage 2 | 445d? | 2002-07-08 A | 2004-03-19 | 60% | 178d? | 2002-07-08 | 2004-03-19 | 445d? | 195d | finish no earlier than 2004-03-19 | S2 | 3560h | 2136h | Rel-6 |  |  |  |  |  |  |  |  |
| 64 | 9.6.2 | GERAN review of the TR | 80d? | 2003-08-25 | 2003-12-12 |  |  | 2003-08-25 | 2003-12-12 | 80d? | 265d | finish no earlier than 2003-12-12 | GP | 640h |  | Rel-6 |  |  |  |  |  |  |  |  |
| 65 | 9.6.3 | RAN review of the TR | 75d? | 2003-08-25 | 2003-12-05 |  |  | 2003-08-25 | 2003-12-05 | 75d? | 270d | finish no earlier than 2003-12-05 | RP | 600h |  | Rel-6 |  |  |  |  |  |  |  |  |
| 66 | 12.7 | **UE positionning** | 930d? | 2000-08-28 A | 2004-03-19 | 45% | 515.37d? | 2000-08-28 | 2004-03-19 | 930d? | 195d |  | RP | 23688h | 10561h | Rel-6 | TSG | LCS2-UEpos |  |  |  |  |  |  |
| 67 | 12.7.1 | UE positioning enhancements - other methods | 805d | 2000-08-28 A | 2003-09-26 | 10% | 724.5d | 2000-08-28 | 2003-09-26 | 805d | 320d | finish no earlier than 2003-06-30 | R2 | 6440h | 644h | Rel-6 | TSG | LCS2-UEpos-enh | M. Beckmann, Siemens | 2457 |  |  |  |  |
| 68 | 12.7.2 | FS on Enhancements to OTDOA Positioning using advanced blanking methods | 320d | 2002-07-01 A | 2003-09-19 | 50% | 160d | 2002-07-01 | 2003-09-19 | 320d | 325d | finish no earlier than 2003-09-19 | R2 | 2560h | 1280h | Rel-6 | TSG | LCS2-UEpos-FSBlank | David Bartlett, Cambridge Positioning Systems |  |  |  |  |  |
| 69 | 12.8 | Open SMLC-SRNC Interface within the UTRAN to support UTRAN Rel4 positioning methods | 700d? | 2001-01-15 A | 2003-09-19 | 95% | 35d? | 2001-01-15 | 2003-09-19 | 700d? | 325d | finish no earlier than 2003-09-19 | R2 | 5600h | 5320h | Rel-6 | TSG | LCS-Rel4Pos | Meik Kottkamp, Siemens | 2475 |  |  |  |  |
| 70 | 9.7.4 | A-GPS minimum performance specification | 206d? | 2003-06-06 | 2004-03-19 |  |  | 2003-06-06 | 2004-03-19 | 206d? | 195d | finish no earlier than 2004-03-19 | R4 | 1648h |  | Rel-6 | TSG | LCS-UEPos-AGPSPerf | Donglin Shen, AT&T Wireless Services |  | donglin.shen@attws.com |  |  |  |
| 71 | 10 | **Uplink TDOA location determination for GSM/GPRS** | 266d | 2002-11-15 A | 2003-11-21 | 9% | 240.93d | 2002-11-15 | 2003-11-21 | 266d | 280d |  | GP | 5544h | 522.59h | Rel-6 | TSG | UTDOA | Gross/Robinson, TruePosition, Inc. |  |  | Paolo |  |  |
| 72 | 10.1 | Addition of U-TDOA in the CS domain | 161d | 2002-11-15 A | 2003-06-27 | 25% | 120.75d | 2002-11-15 | 2003-06-27 | 161d | 385d | finish no earlier than 2003-06-27 | GP | 1288h | 322h | Rel-6 |  | UTDOA-CS |  |  |  |  |  |  |
| 73 | 10.2 | Addition of U-TDOA in the PS domain | 266d | 2002-11-15 | 2003-11-21 |  |  | 2002-11-15 | 2003-11-21 | 266d | 280d | finish no earlier than 2003-11-21 | GP | 2128h |  | Rel-6 |  | UTDOA-PS |  |  |  |  |  |  |
| 74 | 14 | **Security enhancements** | 573d | 2001-01-03 A | 2003-03-14 | 27% | 417d | 2001-01-03 | 2003-03-14 | 573d | 460d |  | S3 | 15312h | 4992h | Rel-6 | TSG | SEC1 | Peter Howard, Vodafone |  | Peter.Howard@vodafone.com | Maurice |  |  |
| 75 | 14.1 | **Enhanced HE control of security (including positive authentication reporting)** | 573d | 2001-01-03 A | 2003-03-14 | 27% | 417d | 2001-01-03 | 2003-03-14 | 573d | 460d |  | S3 | 10728h | 3744h | Rel-6 |  |  | Peter Howard, Vodafone | 2026 | Peter.Howard@vodafone.com |  |  |  |
| 76 | 14.1.1 | Stage 2 | 378d | 2001-01-03 | 2002-06-14 |  |  | 2001-01-03 | 2002-06-14 | 378d | 655d | finish no earlier than 2002-06-14 | S3 | 3024h |  | Rel-6 |  |  |  | 2027 |  |  |  |  |
| 77 | 14.1.3 | **Network domain security** | 195d | 2002-06-17 A | 2003-03-14 | 80% | 39d | 2002-06-17 | 2003-03-14 | 195d | 460d |  | S3 | 3120h | 2496h | Rel-6 | TSG | SEC1-NDS | Geir M. Køien, Telenor |  | Geir-myrdahl.koien@telenor.com |  | Sec |  |
| 78 | 14.1.3.1 | IP network layer security (NDS/IP) | 195d | 2002-06-17 A | 2003-03-14 | 80% | 39d | 2002-06-17 | 2003-03-14 | 195d | 460d | finish no earlier than 2003-03-14 | S3 | 1560h | 1248h | Rel-6 | WG | SEC1-NDS-IP |  |  |  |  |  | TS 33.210 |

Notes:
- 67: This is a building block without particular end date
- 71: Ongoing
- 74: Added BB UE authentication and rapporteur added.
- 75: Added by P-000575 without any dates. 18/10/00: Change of WI title, added hyperlink rapporteur new end date 03/01. New end date and correct Release to be decided S3#18
- 76: New end date and correct Release to be decided S3#18
- 77: WID approved for Rel-6 at SA#17
- 78: Should be complete after SA3#27

| ID | WBS | Task | Duration | Start | Finish | Complete | Remaining | Baseline start | Baseline finish | Baseline duration | Total slack | Constraint | Resources | Work | Actual work | Text1 | Text6 | Text7 | Text8 | Text4 | Text5 | Text3 |
| --- | --- | --- | --- | --- | --- | --- | --- | --- | --- | --- | --- | --- | --- | --- | --- | --- | --- | --- | --- | --- | --- | --- |
| 79 | 16 | **IMS Phase 2** | 864d? | 2000-08-28 A | 2003-12-18 | 47% | 457.28d? | 2000-08-28 | 2003-12-18 | 864d? | 261d |  | S1 | 97233.3h | 43458.6h | IMS2 | Rel-6 | TSG | Sang-Ui |  |  |  |
| 80 | 16.1 | Stage 2 of IMS Phase 2 | 275d | 2002-09-02 A | 2003-09-19 | 80% | 55d | 2002-09-02 | 2003-09-19 | 275d | 325d | finish no earlier than 2003-09-19 | S2 | 2200h | 1760h |  | Rel-6 |  |  |  |  |  |
| 81 | 12.2 | Enhancements to the Cx and Sh interfaces | 136d? | 2003-06-06 A | 2003-12-12 | 10% | 122.4d? | 2003-06-06 | 2003-12-12 | 136d? | 265d | finish no earlier than 2003-12-12 | N4 | 1088h | 108.8h | IMS2-CCR | Rel-6 | WG |  |  |  |  |
| 82 | 16.12 | **IMS Group Management** | 457d? | 2002-03-14 A | 2003-12-12 | 33% | 305.33d? | 2002-03-14 | 2003-12-12 | 457d? | 265d |  | S1 | 7984h | 2649.77h | IMSGM | Rel-6 | TSG |  | Juha Kalliokulju (Nokia) | juha.kalliokulju@nokia.com |  |
| 83 | 16.12.1 | Stage 1 - TS on IMS group management | 193d | 2002-03-14 A | 2002-12-09 | 75% | 48.25d | 2002-03-14 | 2002-12-09 | 193d | 529d | finish no earlier than 2002-12-09 | S1 | 1544h | 1158h |  | Rel-6 | TSG |  | Juha Kalliokulju (Nokia) | juha.kalliokulju@nokia.com |  |
| 84 | 12.3.2 | Stage 2 | 87d? | 2003-05-26 A | 2003-09-23 | 40% | 52.2d? | 2003-05-26 | 2003-09-23 | 87d? | 323d | finish no earlier than 2003-09-23 | S2 | 696h | 278.4h |  | Rel-6 |  |  |  |  |  |
| 85 | 12.3.3 | Stage 3 for IMS Group management (e.g. chat) | 261d? | 2002-12-13 | 2003-12-12 |  |  | 2002-12-13 | 2003-12-12 | 261d? | 265d | finish no earlier than 2003-12-12 | N1 | 2088h |  |  | Rel-6 |  |  | Keith Drage, Lucent | drage@lucent.com |  |
| 86 | 12.4 | **IMS Conferencing** | 290d? | 2002-11-04 A | 2003-12-12 | 47% | 153.68d? | 2002-11-04 | 2003-12-12 | 290d? | 265d |  | N1 | 6288h | 2955.74h |  | Rel-6 |  |  |  |  |  |
| 87 | 12.4.1 | Stage 2 | 235d? | 2002-11-04 A | 2003-09-26 | 77% | 54.05d? | 2002-11-04 | 2003-09-26 | 235d? | 320d | finish no earlier than 2003-09-26 | S2 | 1880h | 1447.6h |  | Rel-6 |  |  |  |  |  |
| 88 | 12.4.2 | Stage 3 | 261d? | 2002-12-13 A | 2003-12-12 | 20% | 208.8d? | 2002-12-13 | 2003-12-12 | 261d? | 265d | finish no earlier than 2003-12-12 | N1 | 2088h | 417.6h |  | Rel-6 |  |  | Keith Drage, Lucent | drage@lucent.com |  |
| 89 | 16.11 | **IMS Messaging** | 457d? | 2002-03-14 A | 2003-12-12 | 64% | 164.05d? | 2002-03-14 | 2003-12-12 | 457d? | 265d |  | S1 | 13560h | 8921.59h | IMSM | Rel-6 | TSG |  | Juha Kalliokulju (Nokia) | juha.kalliokulju@nokia.com |  |
| 90 | 16.11.1 | TR on support of messaging in the IMS | 193d | 2002-03-14 A | 2002-12-09 A | 100% |  | 2002-03-14 | 2002-12-09 | 193d |  | finish no earlier than 2002-12-09 | S1 | 1544h | 1544h | IMSM-TR | Rel-6 | TSG |  | Juha Kalliokulju (Nokia) | juha.kalliokulju@nokia.com |  |
| 91 | 12.5.2 | Stage 1 22.340 | 23d? | 2002-11-11 A | 2002-12-11 A | 100% |  | 2002-11-11 | 2002-12-11 | 23d? |  | finish no earlier than 2002-12-11 | S1 | 184h | 184h | IMSM-TS | Rel-6 | TSG |  | Juha Kalliokulju (Nokia) | juha.kalliokulju@nokia.com | 22.340 |
| 92 | 16.11.2 | **CRs to existing 22-series specifications** | 263d? | 2002-03-14 A | 2003-03-17 | 75% | 65.75d? | 2002-03-14 | 2003-03-17 | 263d? | 459d |  | S1 | 4208h | 3156h | IMSM-CR | Rel-6 | TSG |  | Juha Kalliokulju (Nokia) | juha.kalliokulju@nokia.com |  |
| 93 | 12.5.3.1 | CRs to 22.140 & 22.228 | 263d? | 2002-03-14 A | 2003-03-17 | 75% | 65.75d? | 2002-03-14 | 2003-03-17 | 263d? | 459d | finish no earlier than 2003-03-17 | S1 | 2104h | 1578h | IMSM-CR | Rel-6 | TSG |  | Juha Kalliokulju (Nokia) | juha.kalliokulju@nokia.com | 22.140,22.228 |
| 94 | 16.11.3 | Stage 2 | 235d | 2002-11-04 A | 2003-09-26 | 79% | 49.35d | 2002-11-04 | 2003-09-26 | 235d | 320d | finish no earlier than 2003-09-26 | S2 | 1880h | 1485.2h |  | Rel-6 |  |  |  |  |  |
| 95 | 12.5.5 | Stage 3 for IMS Messaging | 261d? | 2002-12-13 A | 2003-12-12 | 10% | 234.9d? | 2002-12-13 | 2003-12-12 | 261d? | 265d | finish no earlier than 2003-12-12 | N1 | 2088h | 208.8h |  | Rel-6 |  |  | Keith Drage, Lucent | drage@lucent.com |  |
| 96 | 16.7 | **IMS Local services** | 770d? | 2001-01-01 A | 2003-12-12 | 55% | 342.95d? | 2001-01-01 | 2003-12-12 | 770d? | 265d |  | S2 | 10848h | 5192.02h |  | Rel-6 |  |  |  |  | 23.228 |
| 97 | 16.7.1 | Stage 2 | 325d | 2001-01-01 A | 2002-03-29 A | 100% |  | 2001-01-01 | 2002-03-29 | 325d |  | start no earlier than 2001-01-01 | S2 | 2600h | 2600h |  | Rel-6 |  |  |  |  |  |
| 98 | 12.6.2 | Stage 3 for IMS Local services | 261d? | 2002-12-13 | 2003-12-12 |  |  | 2002-12-13 | 2003-12-12 | 261d? | 265d | finish no earlier than 2003-12-12 | N1 | 2088h |  |  | Rel-6 |  |  | Keith Drage, Lucent | drage@lucent.com |  |
| 99 | 12.7 | **Additional SIP Capabilities support not covered by Rel-5** | 285d? | 2002-11-11 A | 2003-12-12 | 51% | 139.69d? | 2002-11-11 | 2003-12-12 | 285d? | 265d |  | N1 | 5688h | 2900.08h |  | Rel-6 |  |  |  |  |  |
| 100 | 12.7.1 | Stage 2 for add SIP cap (e.g. forking) | 165d? | 2002-11-11 A | 2003-06-27 A | 100% |  | 2002-11-11 | 2003-06-27 | 165d? |  | start no earlier than 2002-11-11 | S2 | 1320h | 1320h |  | Rel-6 |  |  |  |  |  |
| 101 | 12.7.2 | Stage 3 for Additional SIP Capabilities | 261d? | 2002-12-13 A | 2003-12-12 | 20% | 208.8d? | 2002-12-13 | 2003-12-12 | 261d? | 265d | finish no earlier than 2003-12-12 | N1 | 2088h | 417.6h |  | Rel-6 |  |  | Keith Drage, Lucent | drage@lucent.com |  |
| 102 | 12.8 | Review additional SIP Capabilities against IMS | 261d? | 2002-12-13 | 2003-12-12 |  |  | 2002-12-13 | 2003-12-12 | 261d? | 265d | finish no earlier than 2003-12-12 | N1 | 2088h |  |  | Rel-6 |  |  | Keith Drage, Lucent | drage@lucent.com |  |

Notes:
- 79: Not yet available: verbally approved at SA15, actual WID to be provided at SA16 by Lucent
- 81: 29./05/2003 CN4: New WID presented for approval at CN#20

| ID | WBS | Task | Duration | Start | Finish | Complete | Remaining | Baseline start | Baseline finish | Baseline duration | Total slack | Constraint | Resources | Work | Actual work | Text1 | Text2 | Text3 | Text4 | Text5 | Text6 | Text7 | Text9 | Text8 |
| --- | --- | --- | --- | --- | --- | --- | --- | --- | --- | --- | --- | --- | --- | --- | --- | --- | --- | --- | --- | --- | --- | --- | --- | --- |
| 103 | 16.5 | **Interworking between IMS and IP networks** | 860d | 2000-08-28 A | 2003-12-12 | 40% | 516d | 2000-08-28 | 2003-12-12 | 860d | 265d |  | N3 | 20640h | 7624h | IMS-CCR-IWIP | BaAS | 23.821, 29.061, 29.162 | Nigel Holland, BT | nigel.holland@bt.com | Rel-6 | TSG | 2048 |  |
| 104 | 16.5.1 | Interworking for 3GPP_SIP and IETF_SIP | 860d | 2000-08-28 A | 2003-12-12 | 70% | 258d | 2000-08-28 | 2003-12-12 | 860d | 265d | finish no earlier than 2003-12-12 | N3 | 6880h | 4816h |  |  | New TR 29.962 | Thomas Belling, Siemens |  | Rel-6 |  |  |  |
| 105 | 16.5.2 | Interworking for IPv6 to IPv4 | 860d | 2000-08-28 A | 2003-12-12 | 10% | 774d | 2000-08-28 | 2003-12-12 | 860d | 265d | finish no earlier than 2003-12-12 | N3 | 6880h | 688h |  |  | 29.163 |  |  | Rel-6 |  |  |  |
| 106 | 16.8 | **Mm interface (CSCF to external IP multimedia network) -- NOT CN3** | 718d | 2001-03-14 A | 2003-12-12 | 38% | 445.16d | 2001-03-14 | 2003-12-12 | 718d | 265d |  | N1 | 9305.28h | 2182.72h |  |  |  |  |  | Rel-6 |  |  |  |
| 107 | 16.8.1 | CN1 part | 718d | 2001-03-14 A | 2003-12-12 | 38% | 445.16d | 2001-03-14 | 2003-12-12 | 718d | 265d | finish no earlier than 2003-12-12 | N1 | 5744h | 2182.72h |  |  |  |  |  | Rel-6 |  |  |  |
| 108 | 16.6.1 | Interworking between IMS and CS networks | 790d? | 2000-08-28 A | 2003-09-05 | 80% | 158d? | 2000-08-28 | 2003-09-05 | 790d? | 335d |  | N3 | 6320h | 5056h | IMS-CCR-IWCS | CCaR | 29.163, 29.061, 24.228, and new CN4 specification | Brendan Mc Williams, Vodafone | brendan.mcwilliams@vf.vodafone.co.uk | Rel-6 | TSG |  |  |
| 109 | 16.10 | Mn interface (IM-MGW to MGCF) enhancements | 335d | 2002-09-02 A | 2003-12-12 | 60% | 134d | 2002-09-02 | 2003-12-12 | 335d | 265d | finish no earlier than 2003-12-12 | N4 | 2680h | 1608h | IMS-CCR-Mn |  |  | Peter Schmitt, Siemens |  | Rel-6 |  |  |  |
| 110 | 12.13 | Mp (MRFC - MRFP) interface protocol definitions | 310d? | 2002-10-07 A | 2003-12-12 | 10% | 279d? | 2002-10-07 | 2003-12-12 | 310d? | 265d | finish no earlier than 2003-12-12 | N4 | 2480h | 248h | IMS-CCR-Mp |  |  | David Sanders, Vodafone |  | Rel-6 |  |  |  |
| 111 | 12.14 | Study of subscriber and operators relationship in IMS and related ISIM requirements for Rel 6” | 20d? | 2002-11-15 A | 2002-12-12 A | 100% |  | 2002-11-15 | 2002-12-12 | 20d? |  | finish no earlier than 2002-12-12 | S1 | 160h | 160h |  |  |  | Juha Kalliokulju (Nokia) | juha.kalliokulju@nokia.com | Rel-6 |  |  |  |
| 112 | 12.15 | Lawful Interception in the 3GPP Rel-6 architecture | 269d? | 2002-12-09 A | 2003-12-18 | 10% | 242.1d? | 2002-12-09 | 2003-12-18 | 269d? | 261d | finish no earlier than 2003-12-18 | S3 | 2152h | 215.2h | SEC1-LI |  | 33.106, 33.107, 33.108 | Berthold Wilhelm | Berthold.Wilhelm@REGTP.DE | Rel-6 | TSG |  |  |
| 113 | 12.16 | IMS Subscription and access scenarios | 130d? | 2002-12-16 A | 2003-06-13 | 58% | 55d? | 2002-12-16 | 2003-06-13 | 130d? | 395d | start no earlier than 2002-12-16 | S1 | 1040h | 600h |  |  | 22.800 |  |  | Rel-6 |  |  |  |
| 114 | 16.4 | Radio optimisation impacts on PS domain architecture | 465d | 2001-12-10 A | 2003-09-19 | 63% | 172.05d | 2001-12-10 | 2003-09-19 | 465d | 325d | finish no earlier than 2003-04-25 | S2 | 3720h | 2343.6h |  |  |  |  |  | Rel-6 | TSG |  | Sang-Ui |
| 115 | 16.3 | **Interoperability and Commonality between IMS using different "IP-connectivity Networks"** | 325d | 2002-09-16 A | 2003-12-12 | 37% | 205.63d | 2002-09-16 | 2003-12-12 | 325d | 265d |  | S2 | 7000h | 1674.8h | IMSCOOP |  |  |  |  | Rel-6 | TSG |  | Sang-Ui |
| 116 | 16.3.1 | 23.228 has been split - Stage 2 | 265d | 2002-09-16 A | 2003-09-19 | 79% | 55.65d | 2002-09-16 | 2003-09-19 | 265d | 325d | finish no earlier than 2003-09-19 | S2 | 2120h | 1674.8h |  |  |  | Balazs Beternyi, Nokia |  | Rel-6 |  |  |  |
| 117 | 16.3.2 | Stage 3 | 305d | 2002-10-14 | 2003-12-12 |  |  | 2002-10-14 | 2003-12-12 | 305d | 265d | finish no earlier than 2003-12-12 | N1 | 2440h |  |  |  |  | Keith Drage, Lucent | drage@lucent.com | Rel-6 |  |  |  |
| 118 | 17 | **Support of Push Services** | 778d | 2001-01-03 A | 2003-12-26 | 85% | 113.27d | 2001-01-03 | 2003-12-26 | 778d | 255d |  | S1 | 12094.6h | 5816.8h | PUSH | CCaR |  | Yoshinori Kitada, NTT Comware |  | Rel-6 | TSG | 1365 | Sang-Ui |
| 119 | 17.1 | Stage 1 | 378d | 2001-01-03 A | 2002-06-14 A | 100% |  | 2001-01-03 | 2002-06-14 | 378d |  | finish no earlier than 2002-06-14 | S1 | 3024h | 3024h |  |  |  |  |  | Rel-6 |  |  |  |
| 120 | 17.2 | TR on feasibility study | 178d | 2001-01-03 A | 2001-09-07 A | 100% |  | 2001-01-03 | 2001-09-07 | 178d |  | finish no earlier than 2001-09-07 | S2 | 1424h | 1424h |  |  |  |  |  | Rel-6 |  |  |  |
| 121 | 17.3 | TR 23.976 on Push Architecture | 295d | 2002-11-11 A | 2003-12-26 | 58% | 123.9d | 2002-11-11 | 2003-12-26 | 295d | 255d | finish no earlier than 2003-12-26 | S2 | 2360h | 1368.8h |  |  |  | Nick Alfano, RIM |  | Rel-6 |  |  |  |
| 122 | 18 | **Multimedia Messaging (MMS) enhancements** | 410d? | 2002-08-15 A | 2004-03-10 | 24% | 310.99d? | 2002-08-15 | 2004-03-10 | 410d? | 202d |  | T2 | 16704h | 5197.28h | MMS6 | Mes |  | Josef Laumen, Siemens | Josef.Laumen@SAL.SIEMENS.DE | Rel-6 | TSG |  | Friedhelm |
| 123 | 18.1 | **Definition of service requirements** | 286d? | 2002-11-15 A | 2003-12-20 | 75% | 71.5d? | 2002-11-15 | 2003-12-20 | 286d? | 260d |  | S1 | 4576h | 3432h | MMS6-SR |  | 22.140 |  |  | Rel-6 |  |  |  |
| 124 | 16.1.1 | Definition of service requirements charging | 286d? | 2002-11-15 A | 2003-12-20 | 75% | 71.5d? | 2002-11-15 | 2003-12-20 | 286d? | 260d | finish no earlier than 2003-12-20 | S1 | 2288h | 1716h |  |  | 22.140 | Josef Laumen, Siemens | Josef.Laumen@SAL.SIEMENS.DE | Rel-6 |  |  |  |
| 125 | 18.2 | Technical realization | 345d | 2002-08-15 A | 2003-12-10 | 20% | 276d | 2002-08-15 | 2003-12-10 | 345d | 267d | finish no earlier than 2003-12-10 | T2 | 2760h | 552h |  |  | 23.140 | Josef Laumen, Siemens | Josef.Laumen@SAL.SIEMENS.DE | Rel-6 |  |  |  |
| 126 | 18.3 | OMA dependencies | 410d | 2002-08-15 | 2004-03-10 |  |  | 2002-08-15 | 2004-03-10 | 410d | 202d | finish no earlier than 2004-03-10 | T2 | 3280h |  |  |  |  |  |  | Rel-6 |  |  |  |
| 127 | 18.4 | MMS formats and codecs | 351d | 2002-08-15 A | 2003-12-18 | 15% | 298.35d | 2002-08-15 | 2003-12-18 | 351d | 261d | finish no earlier than 2003-12-18 | S4 | 2808h | 421.2h |  |  | 26.140 |  |  | Rel-6 |  |  |  |

Notes:
- 103: [DAB 14.02.02] - end date pushed back to March 2003
- 104: [DAB - 23.05.03] - TR is complete in CN
- 105: [DAB - 14.02.02] - Requirements still not clear from SA2
- 106: [DAB - 23.05.03] - IS NOT THE RESPO OF CN3
- 108: [DAB - 23.05.03] - Remove ITU dependancies
- 109: 17th May 2002, CN4; Will be handled in Rel-6 / 02/08/2002 CN4: WID approved at CN4#15 (N4-020997) / 01/09/2002 KK: WID approved at CN#17 (NP-020494) / 15/11/2002CN4: Target will be CN#20 (NP-020600) / 14/03/2003CN#19: Target will be CN#22 (NP-030115)
- 110: 27/11/2002 KK: WID approved at CN#18 (NP-020601) / 27/11/2002CN4: Target will be CN#20 / 29/05/2003 CN4: No change at CN4#19
- 114: TO BE DELETED 10/03 IF NO CONTRIB
- 118: AS: Changed from FS to actual support of Push
- 120: Stage 2 on hold, waiting for requirements.

| ID | WBS | Task | Duration | Start | Finish | Complete | Remaining | Baseline start | Baseline finish | Baseline duration | Total slack | Constraint | Resources | Work | Actual work | Text1 | Text2 | Text6 | Text7 | Text8 | Text3 | Text4 | Text5 | Text9 |
| --- | --- | --- | --- | --- | --- | --- | --- | --- | --- | --- | --- | --- | --- | --- | --- | --- | --- | --- | --- | --- | --- | --- | --- | --- |
| 128 | 19 | **Rel-6 MExE enhancements** | 326d | 2002-03-08 A | 2003-06-06 A | 100% |  | 2002-03-08 | 2003-06-06 | 326d |  |  | T2 | 7328h | 7328h | MEXE6 | Ter | Rel-6 | TSG | Friedhelm |  |  |  |  |
| 129 | 19.1 | MExE Rel-6 Improvements and Investigations | 264d | 2002-03-08 A | 2003-03-12 A | 100% |  | 2002-03-08 | 2003-03-12 | 264d |  | finish no earlier than 2003-03-12 | T2 | 2112h | 2112h | MEXE6-ENHANC | Ter | Rel-6 | TSG |  | 22.057, 23.057 | Lars Brenk (TTPCom) | lsb_ttpcom@HOTMAIL.COM |  |
| 130 | 19.2 | MExE Run-Time Independent Framework Feasibility Study | 326d | 2002-03-08 A | 2003-06-06 A | 100% |  | 2002-03-08 | 2003-06-06 | 326d |  | finish no earlier than 2003-06-06 | T2 | 2608h | 2608h | MEXE6-RTIF | Ter | Rel-6 | TSG |  | 22.857 | Aaron Cohen (Intel) | Aaron.Cohen@intel.com |  |
| 131 | 21 | Subscription Management | 841d | 2000-12-29 A | 2004-03-19 | 60% | 336.4d | 2000-12-29 | 2004-03-19 | 841d | 195d | finish no earlier than 2004-03-19 | S5 | 6728h | 4036.8h | SM |  | Rel-6 | TSG | Adrian | 32.140/1, 32.171/2 | Istvan ABA (T-Mobile Austria) | istvan.aba@t-mobile.at |  |
| 132 | 22 | **Support of Presence Capability** | 720d? | 2001-03-19 A | 2003-12-19 | 77% | 167.7d? | 2001-03-19 | 2003-12-19 | 720d? | 260d |  | S1 | 18736h | 14372h | PRESNC |  | Rel-6 | TSG | Michael |  | Mark Cataldo, Motorola |  | 11004 |
| 133 | 22.1 | Stage 1 | 610d | 2001-03-19 A | 2003-07-18 | 95% | 30.5d | 2001-03-19 | 2003-07-18 | 610d | 370d | finish no earlier than 2003-07-18 | S1 | 4880h | 4636h |  |  | Rel-6 |  |  |  |  |  | 11005 |
| 134 | 22.2 | Stage 2 | 268d | 2001-09-12 A | 2002-09-20 A | 100% |  | 2001-09-12 | 2002-09-20 | 268d |  | finish no earlier than 2002-09-20 | S2 | 2144h | 2144h |  |  | Rel-6 | TSG |  |  |  |  |  |
| 135 | 22.3 | Stage 3 | 450d | 2002-04-01 A | 2003-12-19 | 65% | 157.5d | 2002-04-01 | 2003-12-19 | 450d | 260d | start no earlier than 2002-04-01 | N1 | 3600h | 2340h |  |  | Rel-6 |  |  |  | Keith Drage, Lucent | drage@lucent.com |  |
| 136 | 19.4 | Media Codecs and Formats for IMS Messaging and Presence | 136d? | 2003-06-12 A | 2003-12-18 | 65% | 47.6d? | 2003-06-12 | 2003-12-18 | 136d? | 261d | finish no earlier than 2003-12-18 | S4 | 1088h | 707.2h | COFIMP |  | Rel-6 | TSG |  |  | Harri Honko (Nokia) | harri.honko@nokia.com |  |
| 137 | 22.4 | Security issues | 79d | 2002-08-26 A | 2002-12-12 | 20% | 63.2d | 2002-08-26 | 2002-12-12 | 79d | 526d | finish no earlier than 2002-12-12 | S3 | 632h | 126.4h |  |  | Rel-6 |  |  |  |  |  |  |
| 138 | 22.5 | USIM issues | 79d | 2002-03-04 | 2002-06-20 |  |  | 2002-03-04 | 2002-06-20 | 79d | 651d | start no earlier than 2002-03-04 | T3 | 632h |  |  |  | Rel-6 |  |  |  |  |  |  |
| 139 | 25 | **Enhanced A/Gb feasibility study** | 51d? | 2002-08-30 A | 2002-11-08 | 75% | 12.75d? | 2002-08-30 | 2002-11-08 | 51d? | 550d |  | GP | 4080h | 3162h | AGbEnFS |  | Rel-6 | TSG | Paolo |  | J-L Carrizo, Vodafone | jose-luis.carrizo@vodafone.co.uk |  |
| 140 | 25.1 | **Feasibility study on A/Gb enhancements** | 51d? | 2002-08-30 A | 2002-11-08 | 75% | 12.75d? | 2002-08-30 | 2002-11-08 | 51d? | 550d |  | G2 | 3672h | 2856h | AGbEnFS-FS |  | Rel-6 | TSG |  |  |  |  |  |
| 141 | 25.1.1 | Requirements for the support of conversational services | 51d | 2002-08-30 A | 2002-11-08 A | 100% |  | 2002-08-30 | 2002-11-08 | 51d |  | finish no earlier than 2002-11-08 | GP | 408h | 408h |  |  | Rel-6 |  |  |  |  |  |  |
| 142 | 20.1.2 | Identification of the different building blocks for the provision of conversational services on the existing A/Gb protocol stack | 51d? | 2002-08-30 A | 2002-11-08 A | 100% |  | 2002-08-30 | 2002-11-08 | 51d? |  | finish no earlier than 2002-11-08 | GP | 408h | 408h |  |  | Rel-6 |  |  |  |  |  |  |
| 143 | 20.1.3 | Outline of impact and feasibility of these building blocks and their different solutions | 51d? | 2002-08-30 A | 2002-11-08 A | 100% |  | 2002-08-30 | 2002-11-08 | 51d? |  | finish no earlier than 2002-11-08 | GP | 408h | 408h |  |  | Rel-6 |  |  |  |  |  |  |
| 144 | 25.1.2 | Identification of the different building blocks for the provision of conversational services on the existing A/Gb protocol stack | 51d | 2002-08-30 | 2002-11-08 |  |  | 2002-08-30 | 2002-11-08 | 51d | 550d | finish no earlier than 2002-11-08 | G2 | 408h |  |  |  | Rel-6 |  |  |  |  |  |  |
| 145 | 25.1.3 | Outline of impact and feasibility of these building blocks and their different solutions | 51d | 2002-08-30 | 2002-11-08 |  |  | 2002-08-30 | 2002-11-08 | 51d | 550d | finish no earlier than 2002-11-08 | G2 | 408h |  |  |  | Rel-6 |  |  |  |  |  |  |
| 146 | 25.1.4 | Impact on 3GPP architecture and requirement to co-ordinatge with other TSGs (CN, SA) | 51d | 2002-08-30 A | 2002-11-08 A | 100% |  | 2002-08-30 | 2002-11-08 | 51d |  | finish no earlier than 2002-11-08 | GP | 408h | 408h |  |  | Rel-6 |  |  |  |  |  |  |
| 147 | 25.1.5 | Standardisation effort | 51d | 2002-08-30 A | 2002-11-08 A | 100% |  | 2002-08-30 | 2002-11-08 | 51d |  | finish no earlier than 2002-11-08 | GP | 408h | 408h |  |  | Rel-6 |  |  |  |  |  |  |
| 148 | 25.1.6 | Dependency to other features | 51d | 2002-08-30 A | 2002-11-08 A | 100% |  | 2002-08-30 | 2002-11-08 | 51d |  | finish no earlier than 2002-11-08 | GP | 408h | 408h |  |  | Rel-6 |  |  |  |  |  |  |
| 149 | 26 | **Flexible Layer One for GERAN** | 1015d | 2000-01-03 A | 2003-11-21 | 30% | 711.22d | 2000-01-03 | 2003-11-21 | 1015d | 280d |  | GP | 65007h | 16711.8h | FLOGER |  | Rel-6 | TSG | Paolo |  | Benoist Sébire | benoist.sebire@nokia.com |  |
| 150 | 26.1 | **Realisation of a Flexible Layer One** | 910d | 2000-01-03 A | 2003-06-27 | 40% | 546d | 2000-01-03 | 2003-06-27 | 910d | 385d |  | GP | 29488h | 11795.2h | FLOGER-Real |  | Rel-6 |  |  |  | Benoist Sébire | benoist.sebire@nokia.com |  |
| 151 | 26.1.1 | Technical Report | 311d | 2002-04-19 A | 2003-06-27 | 40% | 186.6d | 2002-04-19 | 2003-06-27 | 311d | 385d | finish no earlier than 2003-06-27 | GP | 2488h | 995.2h |  |  | Rel-6 |  |  |  |  |  |  |
| 152 | 26.1.2 | Architecture in 45.001 and 43.051 | 311d | 2002-04-19 A | 2003-06-27 | 40% | 186.6d | 2002-04-19 | 2003-06-27 | 311d | 385d | finish no earlier than 2003-06-27 | G1 | 2488h | 995.2h |  |  | Rel-6 |  |  |  |  |  |  |
| 153 | 26.1.3 | Multiplexing in 45.002 | 311d | 2002-04-19 A | 2003-06-27 | 40% | 186.6d | 2002-04-19 | 2003-06-27 | 311d | 385d | finish no earlier than 2003-06-27 | G1 | 2488h | 995.2h |  |  | Rel-6 |  |  |  |  |  |  |
| 154 | 26.1.4 | Channel Coding in 45.003 | 311d | 2002-04-19 A | 2003-06-27 | 40% | 186.6d | 2002-04-19 | 2003-06-27 | 311d | 385d | finish no earlier than 2003-06-27 | G1 | 2488h | 995.2h |  |  | Rel-6 |  |  |  |  |  |  |
| 155 | 26.1.5 | Performance Requirements in 45.005 | 910d | 2000-01-03 A | 2003-06-27 | 40% | 546d | 2000-01-03 | 2003-06-27 | 910d | 385d | finish no earlier than 2003-06-27 | G1 | 7280h | 2912h |  |  | Rel-6 |  |  |  |  |  |  |
| 156 | 26.1.6 | Radio subsystem link control in 45.008 | 311d | 2002-04-19 A | 2003-06-27 | 40% | 186.6d | 2002-04-19 | 2003-06-27 | 311d | 385d | finish no earlier than 2003-06-27 | G1 | 2488h | 995.2h |  |  | Rel-6 |  |  |  |  |  |  |
| 157 | 26.1.7 | Requirements in 44.004 | 311d | 2002-04-19 A | 2003-06-27 | 40% | 186.6d | 2002-04-19 | 2003-06-27 | 311d | 385d | finish no earlier than 2003-06-27 | G2 | 2488h | 995.2h |  |  | Rel-6 |  |  |  |  |  |  |

Notes:
- 131: az: TSG appr. 9/03=>3/04. New TSs 32.171/2. Changed Rapp: Michael Eder (Nokia)=> Istvan ABA (T-Mobile Austria).
- 132: A Sultan merged "Presence Service Enhancements" (UID31028, PRES1) to this feature as no answer was provided on why Presence and Presence Encmts had same target completion date
- 136: Also for 31022 IMS Messaging
- 137: LSs handled in SA3. WID approved SA#17 Contribution at S3#25 & following e-mail discussion.
- 139: Closed
- 149: Nokia, Ericsson, Siemens, Telia
- 150: Started

| ID | WBS | Task | Duration | Start | Finish | Complete | Remaining | Baseline start | Baseline finish | Baseline duration | Total slack | Constraint | Resources | Work | Actual work | Text1 | Text4 | Text5 | Text6 | Text3 | Text8 | Text7 | Text9 |
| --- | --- | --- | --- | --- | --- | --- | --- | --- | --- | --- | --- | --- | --- | --- | --- | --- | --- | --- | --- | --- | --- | --- | --- |
| 158 | 26.2 | **Signalling and protocol support for a Flexible Layer One** | 311d | 2002-04-19 A | 2003-06-27 | 30% | 217.7d | 2002-04-19 | 2003-06-27 | 311d | 385d |  | G2 | 7464h | 2239.2h | FLOGER-SigPro | Benoist Sébire | benoist.sebire@nokia.com | Rel-6 |  |  |  |  |
| 159 | 26.2.1 | Modifications to RLC/MAC in 44.060 and 44.160 | 311d | 2002-04-19 A | 2003-06-27 | 30% | 217.7d | 2002-04-19 | 2003-06-27 | 311d | 385d | finish no earlier than 2003-06-27 | G2 | 2488h | 746.4h |  |  |  | Rel-6 |  |  |  |  |
| 160 | 26.2.2 | Modifications to RRC in 44.118 and 44.018 | 311d | 2002-04-19 A | 2003-06-27 | 30% | 217.7d | 2002-04-19 | 2003-06-27 | 311d | 385d | finish no earlier than 2003-06-27 | G2 | 2488h | 746.4h |  |  |  | Rel-6 |  |  |  |  |
| 161 | 26.3 | **Security for a Flexible Layer One** | 311d | 2002-04-19 A | 2003-06-27 | 5% | 295.45d | 2002-04-19 | 2003-06-27 | 311d | 385d |  | S3, G2 | 4943.04h | 247.15h | FLOGER-SecFLO | Benoist Sébire | benoist.sebire@nokia.com | Rel-6 |  |  |  |  |
| 162 | 26.3.1 | Ciphering in 44.160,44.118, 44.060 and 44.018 | 311d | 2002-04-19 A | 2003-06-27 | 5% | 295.45d | 2002-04-19 | 2003-06-27 | 311d | 385d | finish no earlier than 2003-06-27 | S3, G2 | 2488h | 124.4h |  |  |  | Rel-6 |  |  |  |  |
| 163 | 26.4 | **GERAN MS Conformance test for the Flexible Layer One** | 260.5d | 2002-11-22 | 2003-11-21 |  |  | 2002-11-22 | 2003-11-21 | 260.5d | 280d |  | G4; G5 | 8336h |  | FLOGER-Msconf | Benoist Sébire | benoist.sebire@nokia.com | Rel-6 |  |  |  |  |
| 164 | 26.4.1 | MS Test in 51.010 | 260.5d | 2002-11-22 | 2003-11-21 |  |  | 2002-11-22 | 2003-11-21 | 260.5d | 280d | finish no earlier than 2003-11-21 | G4; G5 | 4168h |  |  |  |  | Rel-6 |  |  |  |  |
| 165 | 26.5 | **GERAN BTS Conformance test for the Flexible Layer One** | 416d | 2002-04-19 | 2003-11-21 |  |  | 2002-04-19 | 2003-11-21 | 416d | 280d |  | G3 | 6656h |  | FLOGER-BTSconf | Benoist Sébire | benoist.sebire@nokia.com | Rel-6 |  |  |  |  |
| 166 | 26.5.1 | BTS Test in 51.021 | 416d | 2002-04-19 | 2003-11-21 |  |  | 2002-04-19 | 2003-11-21 | 416d | 280d | finish no earlier than 2003-11-21 | G3 | 3328h |  |  |  |  | Rel-6 |  |  |  |  |
| 167 | 27 | Uplink TDOA feasibility study | 151d | 2001-11-30 A | 2002-06-28 A | 100% |  | 2001-11-30 | 2002-06-28 | 151d |  | finish no earlier than 2002-06-28 | GP | 1208h | 1208h | TDOAF | Bob Gross, TruePosition, Inc. | rlgross@trueposition.com | Rel-6 | 45.811 | Paolo |  |  |
| 168 | 28 | **Multimedia Broadcast and Multicast Service** | 746d | 2001-05-11 A | 2004-03-19 | 22% | 579.67d | 2001-05-11 | 2004-03-19 | 746d | 195d |  | S1 | 52505.6h | 10448.3h | MBMS |  |  | Rel-6 |  | Michael | TSG |  |
| 169 | 28.1 | Stage 1 | 232d | 2001-05-11 A | 2002-04-01 A | 100% |  | 2001-05-11 | 2002-04-01 | 232d |  | finish no earlier than 2002-04-01 | S1 | 1856h | 1856h |  |  |  | Rel-6 | 22.146, 22.101 |  |  | 11003 |
| 170 | 28.2 | **Stage 2** | 520d | 2001-09-24 A | 2003-09-19 | 90% | 53.63d | 2001-09-24 | 2003-09-19 | 520d | 325d |  | S2 | 8360h | 5091.6h |  |  |  | Rel-6 |  |  | TSG |  |
| 171 | 28.2.1 | TR on Architectural Study | 240d | 2001-09-24 A | 2002-08-23 A | 100% |  | 2001-09-24 | 2002-08-23 | 240d |  | finish no earlier than 2002-08-23 | S2 | 1920h | 1920h |  |  |  | Rel-6 |  |  |  |  |
| 172 | 28.2.2 | Stage 2 Specification Work | 285d | 2002-08-19 A | 2003-09-19 | 81% | 54.15d | 2002-08-19 | 2003-09-19 | 285d | 325d | finish no earlier than 2003-06-06 | S2 | 2280h | 1846.8h |  |  |  | Rel-6 |  |  |  |  |
| 173 | 28.3 | Introduction of MBMS in RAN | 579d | 2002-01-01 A | 2004-03-19 | 20% | 463.2d | 2002-01-01 | 2004-03-19 | 579d | 195d | finish no earlier than 2004-03-19 | R2 | 4632h | 926.4h | MBMS-RAN | Juho Pirskanen , Nokia | juho.pirskanen@nokia.com | Rel-6 |  |  | TSG | 2481 |
| 174 | 28.4 | Support of the MBMS in CN protocols | 389d | 2002-06-18 A | 2003-12-12 | 10% | 350.1d | 2002-06-18 | 2003-12-12 | 389d | 265d | finish no earlier than 2003-12-12 | N1 | 3112h | 311.2h |  |  |  | Rel-6 |  |  | TSG |  |
| 175 | 28.5 | Security Aspects of Multimedia Broadcast/Multicast Service (MBMS) | 175d | 2002-07-01 A | 2003-02-28 | 20% | 140d | 2002-07-01 | 2003-02-28 | 175d | 470d | finish no earlier than 2003-02-28 | S3 | 1400h | 280h | MBMS | Escott, Adrian, Hutchison 3G UK | adrian.escott@hutchison3g.com | Rel-6 |  |  | TSG |  |
| 176 | 28.6 | **Support of MBMS in GERAN** | 321d | 2002-08-30 A | 2003-11-21 | 7% | 297.81d | 2002-08-30 | 2003-11-21 | 321d | 280d |  | GP | 27456h | 1983.08h | MBMS-GERAN |  |  | Rel-6 |  |  | TSG |  |
| 177 | 28.6.1 | Impact on the logical and physical channels | 321d | 2002-08-30 A | 2003-11-21 | 10% | 288.9d | 2002-08-30 | 2003-11-21 | 321d | 280d | finish no earlier than 2003-11-21 | GP | 2568h | 256.8h |  |  |  | Rel-6 |  |  |  |  |
| 178 | 28.6.2 | Simultaneous support of MBMS services | 216d | 2002-08-30 | 2003-06-27 |  |  | 2002-08-30 | 2003-06-27 | 216d | 385d | finish no earlier than 2003-06-27 | G1 | 1728h |  |  |  |  | Rel-6 |  |  |  |  |
| 179 | 28.6.3 | Simultaneous support of MBMS and non-MBMS services | 216d | 2002-08-30 | 2003-06-27 |  |  | 2002-08-30 | 2003-06-27 | 216d | 385d | finish no earlier than 2003-06-27 | G1 | 1728h |  |  |  |  | Rel-6 |  |  |  |  |
| 180 | 28.6.4 | Re-synchronisation at cell change | 216d | 2002-08-30 | 2003-06-27 |  |  | 2002-08-30 | 2003-06-27 | 216d | 385d | finish no earlier than 2003-06-27 | G2 | 1728h |  |  |  |  | Rel-6 |  |  |  |  |
| 181 | 28.6.5 | Decision making process between point-to-point or pont-to-multipoint configurations | 321d | 2002-08-30 A | 2003-11-21 | 10% | 288.9d | 2002-08-30 | 2003-11-21 | 321d | 280d | finish no earlier than 2003-11-21 | GP | 2568h | 256.8h |  |  |  | Rel-6 |  |  |  |  |
| 182 | 28.6.6 | MBMS channel allocations procedures to multiple MSs | 321d | 2002-08-30 A | 2003-11-21 | 10% | 288.9d | 2002-08-30 | 2003-11-21 | 321d | 280d | finish no earlier than 2003-11-21 | GP | 2568h | 256.8h |  |  |  | Rel-6 |  |  |  |  |
| 183 | 28.6.7 | Changes to the Gb interface | 321d | 2002-08-30 A | 2003-11-21 | 10% | 288.9d | 2002-08-30 | 2003-11-21 | 321d | 280d | finish no earlier than 2003-11-21 | GP | 2568h | 256.8h |  |  |  | Rel-6 |  |  |  |  |
| 184 | 28.6.8 | GERAN specific changes to the Iu-ps interface | 321d | 2002-08-30 A | 2003-11-21 | 10% | 288.9d | 2002-08-30 | 2003-11-21 | 321d | 280d | finish no earlier than 2003-11-21 | GP | 2568h | 256.8h |  |  |  | Rel-6 |  |  |  |  |
| 185 | 28.6.9 | Interaction between MBMS and Iu-flex | 321d | 2002-08-30 A | 2003-11-21 | 10% | 288.9d | 2002-08-30 | 2003-11-21 | 321d | 280d | finish no earlier than 2003-11-21 | GP | 2568h | 256.8h |  |  |  | Rel-6 |  |  |  |  |
| 186 | 28.6.10 | Security aspects | 321d | 2002-08-30 A | 2003-11-21 | 10% | 288.9d | 2002-08-30 | 2003-11-21 | 321d | 280d | finish no earlier than 2003-11-21 | GP | 2568h | 256.8h |  |  |  | Rel-6 |  |  |  |  |
| 187 | 28.6.11 | MS conformance tests | 216d | 2002-08-30 | 2003-06-27 |  |  | 2002-08-30 | 2003-06-27 | 216d | 385d | finish no earlier than 2003-06-27 | G5 | 1728h |  |  |  |  | Rel-6 |  |  |  |  |

Notes:
- 158: Started
- 161: Started
- 163: Not started
- 165: Not started
- 168: Title renamed at SA#13
- 169: This may or may not be a separate stage 1. In the meantime, CRs are proposed for 22.101
- 175: WID approved SA#17

| ID | WBS | Task | Duration | Start | Finish | Complete | Remaining | Baseline start | Baseline finish | Baseline duration | Total slack | Constraint | Resources | Work | Actual work | Text1 | Text6 | Text7 | Text8 | Text3 | Text4 | Text5 |
| --- | --- | --- | --- | --- | --- | --- | --- | --- | --- | --- | --- | --- | --- | --- | --- | --- | --- | --- | --- | --- | --- | --- |
| 188 | 29 | **Speech Recognition and Speech Enabled Services** | 567d? | 2001-10-08 A | 2003-12-09 | 25% | 427.89d? | 2001-10-08 | 2003-12-09 | 567d? | 268d |  | S1 | 10128h | 2484.91h | SRSES | Rel-6 | TSG | Michael |  |  |  |
| 189 | 29.1 | Speech Enabled Services Based on Distributed Speech Recognition (DSR) | 115d | 2001-10-08 A | 2002-03-15 | 95% | 5.75d | 2001-10-08 | 2002-03-15 | 115d | 720d | finish no earlier than 2002-03-15 | S1 | 920h | 874h | DSR | Rel-6 | TSG |  | 22.941, 23.207, 22.243 | D Williams, QUALCOMM, Inc. | Dwilliams@qualcomm.com |
| 190 | 29.2 | TR on Architectural impacts | 152d | 2003-05-12 | 2003-12-09 |  |  | 2003-05-12 | 2003-12-09 | 152d | 268d | finish no earlier than 2003-12-09 | S2 | 1216h |  |  | Rel-6 |  |  |  |  |  |
| 191 | 29.3 | SES codec negotiation at SDP | 183d | 2002-09-23 | 2003-06-04 |  |  | 2002-09-23 | 2003-06-04 | 183d | 402d | finish no earlier than 2003-06-04 | N1 | 1464h |  |  | Rel-6 |  |  |  |  |  |
| 192 | 24.4 | Codec Work to Support Speech Recognition Framework for Automated Voice Services | 249d? | 2002-10-15 A | 2003-09-26 | 25% | 186.75d? | 2002-10-15 | 2003-09-26 | 249d? | 320d | finish no earlier than 2003-09-26 | S4 | 1992h | 498h | SRSES-Codec | Rel-6 | WG |  | 22.243 | David Pearce, Motorola | bdp003@motorola.com |
| 193 | 30 | **Generic User Profile** | 570d | 2001-10-08 A | 2003-12-12 | 41% | 336.61d | 2001-10-08 | 2003-12-12 | 570d | 265d |  | S1 | 23591.8h | 9659.91h | GUP | Rel-6 | TSG | Michael |  |  |  |
| 194 | 30.1 | Stage 1 - Requirements | 430d | 2001-10-08 A | 2003-05-30 | 88% | 50d | 2001-10-08 | 2003-05-30 | 430d | 405d | finish no earlier than 2002-12-09 | S1 | 3440h | 3040h |  | Rel-6 |  |  | 22.240, 22.228 | Paul Amery (Orange) | paul.amery@orange.co.uk |
| 195 | 30.2 | Stage 2 - Data Description Method | 568d | 2001-10-08 A | 2003-12-10 | 20% | 454.4d | 2001-10-08 | 2003-12-10 | 568d | 267d | finish no earlier than 2003-12-10 | T2 | 4544h | 908.8h |  | Rel-6 | WG |  | 23.241 | Kurt Bischinger (T-Mobile AUSTRIA) | kurt.bischinger@t-mobile.at |
| 196 | 30.3 | Stage 2 - Architecture | 355d | 2002-01-28 A | 2003-06-06 A | 100% |  | 2002-01-28 | 2003-06-06 | 355d |  | finish no earlier than 2003-06-06 | S2 | 2840h | 2840h |  | Rel-6 |  |  | 23.240 | Nacho Uzquiano (Telefonica) | uzquiano_ji@tsm.es |
| 197 | 30.4 | Stage 3 - Common objects | 568d | 2001-10-08 A | 2003-12-10 | 10% | 511.2d | 2001-10-08 | 2003-12-10 | 568d | 267d | finish no earlier than 2003-12-10 | T2 | 4544h | 454.4h |  | Rel-6 | WG |  | 24.241 |  |  |
| 198 | 30.5 | Stage 3 - Network | 149.98d | 2003-05-19 A | 2003-12-12 | 15% | 127.48d | 2003-05-19 | 2003-12-12 | 149.98d | 265d | finish no earlier than 2003-12-12 | N4 | 1199.84h | 179.97h |  | Rel-6 |  |  | 29.240 |  |  |
| 199 | 30.6 | Security Aspects | 308d | 2002-07-16 A | 2003-09-18 | 15% | 261.8d | 2002-07-16 | 2003-09-18 | 308d | 326d | finish no earlier than 2003-09-18 | S3 | 2464h | 369.6h |  | Rel-6 | WG |  | 33.102, 33.203, 33.210 | Owen, Bradley | bvowen@lucent.com |
| 200 | 31 | **Digital Rights Management** | 380d? | 2001-10-08 A | 2003-03-21 | 49% | 194.82d? | 2001-10-08 | 2003-03-21 | 380d? | 455d |  | S1 | 7200h | 3508.61h | DRM | Rel-6 | TSG | Michael |  |  |  |
| 201 | 31.1 | Requirements | 179d | 2001-10-08 A | 2002-06-13 A | 100% |  | 2001-10-08 | 2002-06-13 | 179d |  | finish no earlier than 2002-06-13 | S1 | 1432h | 1432h |  | Rel-6 |  |  |  | Nicholas Wood, Openwave Systems | nicholas.wood@openwave.com |
| 202 | 26.2 | Monitoring of Stages 2 and 3 progress (actual work to be done by OMA) | 155d? | 2002-08-19 | 2003-03-21 |  |  | 2002-08-19 | 2003-03-21 | 155d? | 455d | start no earlier than 2002-08-19 | S1 | 1240h |  |  | Rel-6 |  |  |  |  |  |
| 203 | 31.3 | Security | 186d | 2002-06-17 A | 2003-03-03 | 40% | 111.6d | 2002-06-17 | 2003-03-03 | 186d | 469d | finish no earlier than 2003-03-03 | S3 | 1488h | 595.2h |  | Rel-6 |  |  |  |  |  |
| 204 | 32 | **WLAN-UMTS Interworking** | 1030d? | 2000-01-03 A | 2003-12-12 | 79% | 218.45d? | 2000-01-03 | 2003-12-12 | 1030d? | 265d |  | S1 | 29136h | 22956.5h | WLAN | Rel-6 | TSG | Michael |  | Fredric Paint, Telenor | frederic.paint@telenor.com |
| 205 | 32.1 | Technical Report | 900d? | 2000-01-03 A | 2003-06-13 | 99% | 9d? | 2000-01-03 | 2003-06-13 | 900d? | 395d | finish no earlier than 2003-06-13 | S1 | 7200h | 7128h | WLAN-TR | Rel-6 |  |  | 22.934, 22.101, 22.105 | Fredric Paint, Telenor | frederic.paint@telenor.com |
| 206 | 27.2 | CRs to implement WLAN | 900d? | 2000-01-03 A | 2003-06-13 | 85% | 135d? | 2000-01-03 | 2003-06-13 | 900d? | 395d | finish no earlier than 2003-06-13 | S1 | 7200h | 6120h | WLAN-CR | Rel-6 |  |  | 22.934, 22.101, 22.105, 22.115 | Fredric Paint, Telenor | frederic.paint@telenor.com |
| 207 | 32.2 | Architecture Definition | 395d | 2002-03-25 A | 2003-09-26 | 86% | 55.3d | 2002-03-25 | 2003-09-26 | 395d | 320d | finish no earlier than 2003-09-26 | S2 | 3160h | 2717.6h |  | Rel-6 | TSG |  |  |  |  |
| 208 | 32.3 | Security | 125d | 2002-09-30 A | 2003-03-21 | 30% | 87.5d | 2002-09-30 | 2003-03-21 | 125d | 455d | finish no earlier than 2003-03-21 | S3 | 1000h | 300h |  | Rel-6 | TSG |  | 21.133, 33.106, 33.107, 33.108, 33.200, 33.203, 33.210 | Lopez-Soria, Luis, Ericsson | luis.lopez-soria@ece.ericsson.se |
| 209 | 27.5 | Stage 3 - CN4 aspects | 146d? | 2003-05-23 A | 2003-12-12 | 15% | 124.1d? | 2003-05-23 | 2003-12-12 | 146d? | 265d | finish no earlier than 2003-12-12 | N4 | 1168h | 175.2h | WLAN-IW | Rel-6 | TSG |  | 29.234, 29.061 | Rodriguez ,Raquel, Nokia | raquel.rodriguez@nokia.com |
| 210 | 27.6 | WLAN interworking- stage 3 | 146d? | 2003-05-23 A | 2003-12-12 | 2% | 143.08d? | 2003-05-23 | 2003-12-12 | 146d? | 265d | finish no earlier than 2003-12-12 | N1 | 1168h | 23.36h |  | Rel-6 | WG |  |  |  |  |
| 211 | 33 | **Priority Service** | 347d? | 2002-05-30 A | 2003-09-26 | 52% | 165.04d? | 2002-05-30 | 2003-09-26 | 347d? | 320d |  | S1 | 7512h | 3939.13h | PRIOR | Rel-6 | TSG | Michael |  |  |  |
| 212 | 33.1 | Feasibility Study | 1d | 2002-06-14 A | 2002-06-14 A | 100% |  | 2002-06-14 | 2002-06-14 | 1d |  | finish no earlier than 2002-06-14 | S1 | 8h | 8h | PRIOR-FS | Rel-6 |  | Michael | 22.950 | Biplab K. Pramanik, Telcordia Technologies | bpramani@telcordia.com |
| 213 | 33.2 | Stage 1 - Requirements | 340d | 2002-05-30 A | 2003-09-17 | 85% | 51d | 2002-05-30 | 2003-09-17 | 340d | 327d | finish no earlier than 2003-09-17 | S1 | 2720h | 2312h | PRIOR-SR | Rel-6 |  | Michael |  | James J. Garrahan, Telcordia Technologies | bpramani@telcordia.com |
| 214 | 28.3 | Priority Multimedia Service | 131d? | 2003-03-28 | 2003-09-26 |  |  | 2003-03-28 | 2003-09-26 | 131d? | 320d | finish no earlier than 2003-09-26 | S1 | 1048h |  |  | Rel-6 |  |  |  |  |  |
| 215 | 28.4 | Priority service implementation guide | 131d? | 2003-03-28 A | 2003-09-26 | 20% | 104.8d? | 2003-03-28 | 2003-09-26 | 131d? | 320d | finish no earlier than 2003-09-26 | S1 | 1048h | 209.6h |  | Rel-6 |  |  | 22.952 | Biplab K. Pramanik, Telcordia Technologies | bpramani@telcordia.com |

Notes:
- 191: renamed according to Hannu's indication
- 198: 17 May no activity in CN4 / 02/08/2002 CN4: No activity in CN4 / 12/03/2003CN#19: CN4 have agreed in principle to undertake this work, but there was no substantive input (WID or technical). There is concern over the immaturity of the stage 1 & stage 2 specifications; we believe that we will need 6 months from when the stage 2 specification is stable in order to do the stage 3 work. / 29/05/2003 CN4 : Outline of draft TS approved
- 199: WID approved SA#17. SA WG3 progress slow, depends on progress in other groups.
- 200: Foreseen start and completion dates introduced by MCC (no indication at all on the WID)
- 203: SA3 acknowledge role in WI at SA3#20. Active contribution S3#24, S3#25. S3 WID approved SA#17
- 208: Active contribution S3#24, S3#25. WID approved SA#17
- 209: WID approved at CN#19 / 29/05/2003 CN4: Outline of draft TS approved

| ID | WBS | Task | Duration | Start | Finish | Complete | Remaining | Baseline start | Baseline finish | Baseline duration | Total slack | Constraint | Resources | Work | Actual work | Text1 | Text6 | Text7 | Text8 | Text3 | Text5 | Text4 |
| --- | --- | --- | --- | --- | --- | --- | --- | --- | --- | --- | --- | --- | --- | --- | --- | --- | --- | --- | --- | --- | --- | --- |
| 216 | 34 | **Network Sharing** | 240d? | 2003-01-20 A | 2003-12-19 | 66% | 80.55d? | 2003-01-20 | 2003-12-19 | 240d? | 260d |  | S1 | 8608h | 5719.08h | NTShar | Rel-6 | TSG | Michael |  |  |  |
| 217 | 34.1 | Technical Report | 240d? | 2003-01-20 A | 2003-12-19 | 99% | 2.4d? | 2003-01-20 | 2003-12-19 | 240d? | 260d |  | S1 | 1920h | 1900.8h | NTShar-TR | Rel-6 |  | Michael | 22.951 |  |  |
| 218 | 29.2 | Stage 1 - CRs to implement Network Sharing | 240d? | 2003-01-20 A | 2003-12-19 | 95% | 12d? | 2003-01-20 | 2003-12-19 | 240d? | 260d | finish no earlier than 2003-12-19 | S1 | 1920h | 1824h | NTShar-CR | Rel-6 |  |  | 22.011, 22.101, 22.115, 22.129 |  |  |
| 219 | 29.3 | Stage 2 | 212d? | 2003-02-27 A | 2003-12-19 | 43% | 120.84d? | 2003-02-27 | 2003-12-19 | 212d? | 260d | finish no earlier than 2003-12-19 | S2 | 1696h | 729.28h |  | Rel-6 |  |  |  |  |  |
| 220 | 29.4 | Network sharing - stage 3 | 146d? | 2003-05-23 | 2003-12-12 |  |  | 2003-05-23 | 2003-12-12 | 146d? | 265d | finish no earlier than 2003-12-12 | N1 | 1168h |  |  | Rel-6 | WG |  |  |  |  |
| 221 | 35 | **QoS Improvements** | 375d? | 2002-07-15 A | 2003-12-19 | 49% | 191.82d? | 2000-01-03 | 2003-12-19 | 1035d? | 260d |  | S2 | 6992h | 3415.43h | QoS1 | Rel-6 | TSG | Sang-Ui |  |  |  |
| 222 | 35.1 | FS on Dynamic Policy control enhancements for end-to-end QoS | 375d | 2002-07-15 A | 2003-12-19 | 65% | 131.25d | 2002-07-15 | 2003-12-19 | 375d | 260d | finish no earlier than 2003-12-19 | S2 | 3000h | 1950h | QoS1 | Rel-6 | TSG |  |  | Claire Mousset, Nortel |  |
| 223 | 30.2 | Definition of the Gq interface | 124d? | 2003-07-01 | 2003-12-19 |  |  | 2000-01-03 | 2000-01-03 | 1d? | 260d | start no earlier than 2003-07-01 | S2 | 992h |  |  | Rel-6 |  |  |  |  | Janne Rinne (Nokia) |
| 224 | 36 | **Support for subscriber certificates** | 189d | 2002-02-25 A | 2002-11-14 | 49% | 97.2d | 2002-02-25 | 2002-11-14 | 189d | 546d |  | S3 | 2856h | 1387.2h | SEC1-SC | Rel-6 | TSG | Maurice | 33.102 | valtteri.niemi@nokia.com | Valtteri Niemi, Nokia |
| 225 | 36.1 | Stage 1 | 144d | 2002-02-25 A | 2002-09-12 | 40% | 86.4d | 2002-02-25 | 2002-09-12 | 144d | 591d | finish no earlier than 2002-09-12 | S3 | 1152h | 460.8h |  | Rel-6 |  |  |  |  |  |
| 226 | 36.2 | Architecture review | 24d | 2002-10-14 A | 2002-11-14 A | 100% |  | 2002-10-14 | 2002-11-14 | 24d |  | finish no earlier than 2002-11-14 | S2 | 192h | 192h |  | Rel-6 |  |  |  |  |  |
| 227 | 32 | **Rel-6 OSA enhancements** | 481.85d? | 2002-02-14 A | 2003-12-19 | 63% | 178.34d? | 2002-02-14 | 2003-12-19 | 481.85d? | 260d |  | S1 | 43665.6h | 27504h | OSA3 | Rel-6 | TSG | Adrian | 22.127, 29.198, 29.998 | Chelo.Abarca@alcatel.fr | Chelo ABARCA (Alcatel) |
| 228 | 32.1 | Scope of the Open Service Access Release 6 | 66d? | 2003-03-28 A | 2003-06-27 | 90% | 6.6d? | 2003-03-28 | 2003-06-27 | 66d? | 385d | finish no earlier than 2003-06-27 | S1 | 528h | 475.2h |  | Rel-6 | TSG |  |  |  |  |
| 229 | 38.1 | Support of a Generic Network Interface Function (Stage 1) | 212.1d | 2002-02-27 A | 2003-01-06 A | 100% |  | 2002-02-27 | 2003-01-06 | 212.1d |  | finish no earlier than 2003-01-06 | S1 | 1696.79h | 1696.79h |  | Rel-6 | TSG |  | 22.127 |  |  |
| 230 | 38.2 | Support of a Generic Network Interface Function (Stage 3) | 462d | 2002-02-14 A | 2003-12-19 | 60% | 184.8d | 2002-02-14 | 2003-12-19 | 462d | 260d | finish no earlier than 2003-12-19 | N5 | 3696h | 2217.6h |  | Rel-6 | TSG |  | 29.198, 29.998 |  |  |
| 231 | 38.11 | User Data Management / User data security management (Stage 1) | 212.1d | 2002-02-27 A | 2003-01-06 A | 100% |  | 2002-02-27 | 2003-01-06 | 212.1d |  | finish no earlier than 2003-01-06 | S1 | 1696.79h | 1696.79h |  | Rel-6 | TSG |  | 22.127 |  |  |
| 232 | 38.12 | User Data Management / User data security management (Stage 3) | 462d | 2002-03-14 A | 2003-12-19 | 60% | 184.8d | 2002-03-14 | 2003-12-19 | 462d | 260d | finish no earlier than 2003-12-19 | N5 | 3696h | 2217.6h |  | Rel-6 | TSG |  | 29.198, 29.998 |  |  |
| 233 | 32.6 | Retrieval of Visited Network capabilities | 297d? | 2002-10-31 A | 2003-12-19 | 60% | 118.8d? | 2002-10-31 | 2003-12-19 | 297d? | 260d | finish no earlier than 2003-12-19 | N5 | 2376h | 1425.6h |  | Rel-6 | TSG |  | 29.198, 29.998 |  |  |
| 234 | 32.7 | Access to IP Session information | 297d? | 2002-10-31 A | 2003-12-19 | 60% | 118.8d? | 2002-10-31 | 2003-12-19 | 297d? | 260d | finish no earlier than 2003-12-19 | N5 | 2376h | 1425.6h |  | Rel-6 | TSG |  | 29.198, 29.998 |  |  |
| 235 | 32.8 | Multi Media Messaging function | 297d? | 2002-10-31 A | 2003-12-19 | 60% | 118.8d? | 2002-10-31 | 2003-12-19 | 297d? | 260d | finish no earlier than 2003-12-19 | N5 | 2376h | 1425.6h |  | Rel-6 | TSG |  | 29.198, 29.998 |  |  |
| 236 | 32.9 | Enhanced user privacy in LCS | 297d? | 2002-10-31 A | 2003-12-19 | 60% | 118.8d? | 2002-10-31 | 2003-12-19 | 297d? | 260d | finish no earlier than 2003-12-19 | N5 | 2376h | 1425.6h |  | Rel-6 | TSG |  | 29.198, 29.998 |  |  |
| 237 | 32.10 | Policy management extensions | 297d? | 2002-10-31 A | 2003-12-19 | 60% | 118.8d? | 2002-10-31 | 2003-12-19 | 297d? | 260d | finish no earlier than 2003-12-19 | N5 | 2376h | 1425.6h |  | Rel-6 | TSG |  | 29.198, 29.998 |  |  |
| 238 | 32.11 | Presence and Availability Management (from the PRESNC WI) | 297d? | 2002-10-31 A | 2003-12-19 | 60% | 118.8d? | 2002-10-31 | 2003-12-19 | 297d? | 260d | finish no earlier than 2003-12-19 | N5 | 2376h | 1425.6h |  | Rel-6 | TSG |  | 29.198, 29.998 |  |  |
| 239 | 32.12 | Information Services | 297d? | 2002-10-31 A | 2003-12-19 | 60% | 118.8d? | 2002-10-31 | 2003-12-19 | 297d? | 260d | finish no earlier than 2003-12-19 | N5 | 2376h | 1425.6h |  | Rel-6 | TSG |  | 29.198, 29.998 |  |  |
| 240 | 32.13 | Information Transfer | 297d? | 2002-10-31 A | 2003-12-19 | 60% | 118.8d? | 2002-10-31 | 2003-12-19 | 297d? | 260d | finish no earlier than 2003-12-19 | N5 | 2376h | 1425.6h |  | Rel-6 | TSG |  | 29.198, 29.998 |  |  |
| 241 | 32.14 | OSA interfaces at different levels of abstractions (Parlay X, Web services) | 201d? | 2003-03-14 A | 2003-12-19 | 40% | 120.6d? | 2003-03-14 | 2003-12-19 | 201d? | 260d | finish no earlier than 2003-12-19 | N5 | 1608h | 643.2h |  | Rel-6 | TSG |  | 29.198, 29.998 |  |  |
| 242 | 32.15 | Introduction of migration support mechanism | 201d? | 2003-03-14 A | 2003-12-19 | 60% | 80.4d? | 2003-03-14 | 2003-12-19 | 201d? | 260d | finish no earlier than 2003-12-19 | N5 | 1608h | 964.8h |  | Rel-6 | TSG |  | 29.198, 29.998 |  |  |
| 243 | 32.16 | User Profile | 201d? | 2003-03-14 A | 2003-12-19 | 60% | 80.4d? | 2003-03-14 | 2003-12-19 | 201d? | 260d | finish no earlier than 2003-12-19 | N5 | 1608h | 964.8h |  | Rel-6 | TSG |  | 29.198, 29.998 |  |  |
| 244 | 32.17 | Network functions for end-user/application interaction support | 201d? | 2003-03-14 A | 2003-12-19 | 60% | 80.4d? | 2003-03-14 | 2003-12-19 | 201d? | 260d | finish no earlier than 2003-12-19 | N5 | 1608h | 964.8h |  | Rel-6 | TSG |  | 29.198, 29.998 |  |  |
| 245 | 32.18 | Framework Function for Federation | 201d? | 2003-03-14 A | 2003-12-19 | 60% | 80.4d? | 2003-03-14 | 2003-12-19 | 201d? | 260d | finish no earlier than 2003-12-19 | N5 | 1608h | 964.8h |  | Rel-6 | TSG |  | 29.198, 29.998 |  |  |
| 246 | 32.19 | Enhancements to IP Session Function in OSA for the control and monitor of IP Flows | 201d? | 2003-03-14 A | 2003-12-19 | 60% | 80.4d? | 2003-03-14 | 2003-12-19 | 201d? | 260d | finish no earlier than 2003-12-19 | N5 | 1608h | 964.8h |  | Rel-6 | TSG |  | 29.198, 29.998 |  |  |

Notes:
- 224: Approved at SA#14. This may require BBs from CN1, CN4, SA5 and T3
- 225: Contribution received S3#24, S3#25
- 227: NP-030036 Rev WID replaces SP-020573.
- 246: Ongoing S1 & S2 debate on Architecture support.

| ID | WBS | Task | Duration | Start | Finish | Complete | Remaining | Baseline start | Baseline finish | Baseline duration | Total slack | Constraint | Resources | Work | Actual work | Text1 | Text4 | Text6 | Text7 | Text8 | Text3 | Text5 | Text2 |
| --- | --- | --- | --- | --- | --- | --- | --- | --- | --- | --- | --- | --- | --- | --- | --- | --- | --- | --- | --- | --- | --- | --- | --- |
| 247 | 39 | **Addition of frequency bands to GSM** | 306d | 2002-06-28 A | 2003-08-29 | 8% | 282.04d | 2002-06-28 | 2003-08-29 | 306d | 340d |  | GP | 7760h | 607.71h | TAPS | Torben Themsen | Rel-6 | TSG | Paolo |  |  |  |
| 248 | 39.1 | **Addition of frequency bands to GSM – Changes to core specs** | 26d | 2002-11-15 A | 2002-12-20 A | 100% |  | 2002-11-15 | 2002-12-20 | 26d |  |  | G1 | 416h | 416h | TAPS-Specs | Torben Themsen | Rel-6 | TSG |  |  |  |  |
| 249 | 39.1.1 | Changes to core specs | 26d | 2002-11-15 A | 2002-12-20 A | 100% |  | 2002-11-15 | 2002-12-20 | 26d |  | finish no earlier than 2002-12-20 | G1 | 208h | 208h |  |  | Rel-6 |  |  |  |  |  |
| 250 | 39.2 | **Addition of frequency bands to GSM – Changes for conformance tests** | 306d | 2002-06-28 | 2003-08-29 |  |  | 2002-06-28 | 2003-08-29 | 306d | 340d |  | G4 | 4896h |  | TAPS-Conf | Torben Themsen | Rel-6 |  |  |  |  |  |
| 251 | 39.2.1 | 51.010-1 Add testing | 306d | 2002-06-28 | 2003-08-29 |  |  | 2002-06-28 | 2003-08-29 | 306d | 340d | finish no earlier than 2003-08-29 | G4 | 2448h |  |  |  | Rel-6 |  |  |  |  |  |
| 252 | 40 | **Seamless support of streaming services in A/Gb mode** | 1035d? | 2000-01-03 A | 2003-12-19 | 83% | 176.47d? | 2000-01-03 | 2003-12-19 | 1035d? | 260d |  | GP | 34008h | 22255.7h | SSStrea | José Luis Carrizo Martínez, Vodafone | Rel-6 | TSG | Paolo |  |  |  |
| 253 | 40.1 | **Identification of requirements for streaming** | 1d? | 2003-06-27 A | 2003-06-27 | 90% | 0.1d? | 2003-06-27 | 2003-06-27 | 1d? | 385d |  | G1 | 16h | 15.2h |  |  | Rel-6 |  |  |  |  |  |
| 254 | 34.1.1 | Requirements | 1d? | 2003-06-27 A | 2003-06-27 | 90% | 0.1d? | 2003-06-27 | 2003-06-27 | 1d? | 385d | start no earlier than 2003-06-27 | G1 | 8h | 7.2h |  |  | Rel-6 |  |  |  |  |  |
| 255 | 40.2 | **Performance study of cell change mechanisms** | 910d? | 2000-01-03 A | 2003-06-27 | 90% | 91d? | 2000-01-03 | 2003-06-27 | 910d? | 385d |  | G1 | 29120h | 19748.8h |  |  | Rel-6 |  |  |  |  |  |
| 256 | 34.2.1 | Performance of NACC | 910d? | 2000-01-03 A | 2003-06-27 | 90% | 91d? | 2000-01-03 | 2003-06-27 | 910d? | 385d | finish no earlier than 2003-06-27 | G1 | 7280h | 6552h |  |  | Rel-6 |  |  |  |  |  |
| 257 | 34.2.2 | Performance of cell change in DTM for the PS domain | 910d? | 2000-01-03 A | 2003-06-27 | 90% | 91d? | 2000-01-03 | 2003-06-27 | 910d? | 385d | finish no earlier than 2003-06-27 | G1 | 7280h | 6552h |  |  | Rel-6 |  |  |  |  |  |
| 258 | 34.2.3 | Handover | 910d? | 2000-01-03 A | 2003-06-27 | 90% | 91d? | 2000-01-03 | 2003-06-27 | 910d? | 385d | finish no earlier than 2003-06-27 | G1 | 7280h | 6552h |  |  | Rel-6 |  |  |  |  |  |
| 259 | 40.3 | **Reduction of service interruption times and packet loss during mobility procedures** | 1d? | 2003-06-27 A | 2003-06-27 | 50% | 0.5d? | 2003-06-27 | 2003-06-27 | 1d? | 385d |  | G2 | 40h | 20h |  |  | Rel-6 |  |  |  |  |  |
| 260 | 34.3.1 | Optimisations of existing mechanisms/procedures | 1d? | 2003-06-27 A | 2003-06-27 | 50% | 0.5d? | 2003-06-27 | 2003-06-27 | 1d? | 385d | start no earlier than 2003-06-27 | G2 | 8h | 4h |  |  | Rel-6 |  |  |  |  |  |
| 261 | 34.3.2 | Inter-system NACC | 1d? | 2003-06-27 A | 2003-06-27 | 50% | 0.5d? | 2003-06-27 | 2003-06-27 | 1d? | 385d | start no earlier than 2003-06-27 | G2 | 8h | 4h |  |  | Rel-6 |  |  |  |  |  |
| 262 | 34.3.3 | PS Handover (within GERAN and between GERAN and UTRAN) | 1d? | 2003-06-27 A | 2003-06-27 | 50% | 0.5d? | 2003-06-27 | 2003-06-27 | 1d? | 385d | start no earlier than 2003-06-27 | G2 | 8h | 4h |  |  | Rel-6 |  |  |  |  |  |
| 263 | 34.3.4 | Dependency to other features | 1d? | 2003-06-27 A | 2003-06-27 | 50% | 0.5d? | 2003-06-27 | 2003-06-27 | 1d? | 385d | start no earlier than 2003-06-27 | G2 | 8h | 4h |  |  | Rel-6 |  |  |  |  |  |
| 264 | 40.5 | **MS conformance testing** | 1d? | 2003-12-19 | 2003-12-19 |  |  | 2003-12-19 | 2003-12-19 | 1d? | 260d |  | G4,G5 | 16h |  |  |  | Rel-6 |  |  |  |  |  |
| 265 | 34.4.1 | MS conformance tests | 1d? | 2003-12-19 | 2003-12-19 |  |  | 2003-12-19 | 2003-12-19 | 1d? | 260d | start no earlier than 2003-12-19 | G4,G5 | 8h |  |  |  | Rel-6 |  |  |  |  |  |
| 266 | 34.5 | GERAN A/Gb mode security enhancements | 261d? | 2002-09-26 A | 2003-09-25 | 10% | 234.9d? | 2002-09-26 | 2003-09-25 | 261d? | 321d | finish no earlier than 2003-09-25 | S3 | 2088h | 208.8h |  | Peter Howard, Vodafone | Rel-6 |  |  | 33.102 | peter.howard@vodafone.com |  |
| 267 | 41 | Performance characterisation of default codecs for PS conversational multimedia application | 271d | 2002-09-13 A | 2003-09-26 | 20% | 216.8d | 2002-09-13 | 2003-09-26 | 271d | 320d | finish no earlier than 2003-09-26 | S4 | 2168h | 433.6h | CODCAR | Pasi Ojala (Nokia) | Rel-6 | TSG | Paolo | TR 26.9yz | pasi.s.ojala@nokia.com |  |
| 268 | 42 | Study of Feature Interactions Requirements | 82d | 2002-11-08 A | 2003-03-03 | 20% | 65.6d | 2002-11-08 | 2003-03-03 | 82d | 469d | start no earlier than 2002-11-08 | S1 | 656h | 131.2h | FINTER |  | Rel-6 | TSG | Michael | TR 21.xyz |  |  |
| 269 | 43 | Study on Privacy Capability | 82d | 2002-11-08 A | 2003-03-03 | 15% | 69.7d | 2002-11-08 | 2003-03-03 | 82d | 469d | start no earlier than 2002-11-08 | S1 | 656h | 98.4h | PrivCap | Liz Daniel, Lucent | Rel-6 | TSG | Michael | TR 21.xyz |  |  |
| 270 | 44 | **OAM&P** | 477.3d? | 2002-05-21 A | 2004-03-18 | 28% | 342.76d? | 2002-05-21 | 2004-03-18 | 477.3d? | 196d |  | S5 | 25978.4h | 6879.39h | OAM | Michael TRUSS (Motorola) | Rel-6 | TSG | Adrian | 32-series | Michael.Truss@MOTOROLA.COM |  |
| 271 | 44.1 | Principles, high level Requirements and Architecture | 396d | 2002-09-12 A | 2004-03-18 | 45% | 217.8d | 2002-09-12 | 2004-03-18 | 396d | 196d | finish no earlier than 2004-03-18 | S5 | 3168h | 1425.6h | OAM-AR | Michael TRUSS (Motorola) | Rel-6 | TSG |  | 32.101, 32.102 | Michael.Truss@MOTOROLA.COM | BCaM |
| 272 | 44.2 | Performance Management | 396d | 2002-09-12 A | 2004-03-18 | 40% | 237.6d | 2002-09-12 | 2004-03-18 | 396d | 196d | finish no earlier than 2004-03-18 | S5 | 3168h | 1267.2h | OAM-PM | Christian TOCHE (Nortel Networks) | Rel-6 | TSG |  | 32.41x, 52.402 | toche@NORTELNETWORKS.COM | BCaM |

Notes:
- 248: Ready
- 250: Not started
- 253: Started
- 255: Started
- 259: Started
- 264: Not started
- 266: Possible changes to 33.102 or new specification needed.

| ID | WBS | Task | Duration | Start | Finish | Complete | Remaining | Baseline start | Baseline finish | Baseline duration | Total slack | Constraint | Resources | Work | Actual work | Text1 | Text3 | Text6 | Text7 | Text4 | Text5 | Text8 | Text2 | Text9 |
| --- | --- | --- | --- | --- | --- | --- | --- | --- | --- | --- | --- | --- | --- | --- | --- | --- | --- | --- | --- | --- | --- | --- | --- | --- |
| 273 | 44.3 | **User Equipment Management** | 477.3d? | 2002-05-21 A | 2004-03-18 | 14% | 409.57d? | 2002-05-21 | 2004-03-18 | 477.3d? | 196d |  | S5 | 11562.4h | 1640.75h | OAM-UEM | 32.150 | Rel-6 | TSG |  |  |  |  |  |
| 274 | 38.3.1 | UEM requirements and architecture; Stages 1 and 2 | 396d? | 2002-09-12 A | 2004-03-18 | 30% | 277.2d? | 2002-09-12 | 2004-03-18 | 396d? | 196d | finish no earlier than 2004-03-18 | S5 | 3168h | 950.4h |  | 32.150 (SA5) | Rel-6 | TSG |  |  |  |  |  |
| 275 | 38.3.2 | UEM protocol specification; Stage 3 | 352.3d? | 2002-05-21 | 2003-09-25 |  |  | 2002-05-21 | 2003-09-25 | 352.3d? | 321d | start no earlier than 2002-05-21 | OMA | 2818.4h |  |  | 27.150 (T2) | Rel-6 | TSG |  |  |  |  |  |
| 276 | 38.3.3 | Release 6 User Equipment Management: Security aspects | 301d? | 2002-08-01 A | 2003-09-25 | 10% | 270.9d? | 2002-08-01 | 2003-09-25 | 301d? | 321d | finish no earlier than 2003-09-25 | S3 | 2408h | 240.8h | OAM-UEM-SEC |  | Rel-6 | TSG | Peter Howard (Vodafone) | peter.howard@vodafone.com |  |  |  |
| 277 | 44.4 | Network Infrastructure Management | 396d | 2002-09-12 A | 2004-03-18 | 35% | 257.4d | 2002-09-12 | 2004-03-18 | 396d | 196d | finish no earlier than 2004-03-18 | S5 | 3168h | 1108.8h | OAM-NIM | 32.6xy, 32.3xy | Rel-6 | TSG | Thomas TOVINGER (Ericsson) | Thomas.Tovinger@emw.ericsson.se |  |  |  |
| 278 | 44.5 | Trace Management | 76d | 2003-06-06 A | 2003-09-19 | 65% | 26.6d | 2003-06-06 | 2003-09-19 | 76d | 325d | finish no earlier than 2003-09-19 | S5 | 608h | 395.2h | OEM-Trace | 32.42x, 52.008 | Rel-6 | TSG | Christian TOCHE (Nortel Networks) | toche@NORTELNETWORKS.COM |  |  |  |
| 279 | 38.6 | Subscriber and equipment trace in UTRAN | 76d? | 2003-06-06 | 2003-09-19 |  |  | 2003-06-06 | 2003-09-19 | 76d? | 325d | finish no earlier than 2003-09-19 | R3 | 608h |  | OEM-Trace-RAN |  | Rel-6 | TSG | Yann Sehedi, Nortel | sehedic@nortelnetworks.com |  |  |  |
| 280 | 39 | **Charging Management** | 346d? | 2002-11-21 A | 2004-03-18 | 33% | 230.17d? | 2002-11-21 | 2004-03-18 | 346d? | 196d |  | S5 | 12824h | 4293.13h | CH | 32.2xy | Rel-6 | TSG | Karl-Heinz NENNER (T-Mobile) | karl-heinz.nenner@t-mobile.de | Adrian |  |  |
| 281 | 39.1 | Charging Management for Bearer level | 345d? | 2002-11-22 A | 2004-03-18 | 25% | 258.75d? | 2002-11-22 | 2004-03-18 | 345d? | 196d | finish no earlier than 2004-03-18 | S5 | 2760h | 690h | CH-BC |  | Rel-6 | TSG | Benni ALEXANDER (Nokia) |  |  |  |  |
| 282 | 39.2 | Charging Management for the IMS | 345d? | 2002-11-22 A | 2004-03-18 | 25% | 258.75d? | 2002-11-22 | 2004-03-18 | 345d? | 196d | finish no earlier than 2004-03-18 | S5 | 2760h | 690h | CH-IC |  | Rel-6 | TSG | Ariel SHARON (Lucent) |  |  |  |  |
| 283 | 39.3 | Charging Management for the Service domain | 345d? | 2002-11-22 A | 2004-03-18 | 25% | 258.75d? | 2002-11-22 | 2004-03-18 | 345d? | 196d | finish no earlier than 2004-03-18 | S5 | 2760h | 690h | CH-SC |  | Rel-6 | TSG | Gerald GÖRMER (Siemens) |  |  |  |  |
| 284 | 39.4 | Overall architectural aspects of IP flow based bearer level charging | 222d? | 2002-11-21 A | 2003-09-26 | 73% | 59.94d? | 2002-11-21 | 2003-09-26 | 222d? | 320d | finish no earlier than 2003-09-26 | S2 | 1776h | 1296.48h |  |  | Rel-6 |  |  |  |  |  |  |
| 285 | 13 | **Rel-6 UICC/USIM enhancements and interworking** | 778d | 2000-09-25 A | 2003-09-17 | 58% | 325.78d | 2000-09-25 | 2003-09-17 | 778d | 327d |  | T3 | 24200h | 12454.3h | USAT1 |  | Rel-6 | TSG |  |  | Claus | Ter | 1800 |
| 286 | 13.1 | **UICC API** | 391d | 2002-03-20 A | 2003-09-17 | 25% | 292.05d | 2002-03-20 | 2003-09-17 | 391d | 327d |  | T3 | 6912h | 1749.19h | USAT1-API |  | Rel-6 |  |  |  |  | Ter | 1802 |
| 287 | 13.1.1 | Java API Test specification | 133d | 2002-03-20 A | 2002-09-20 | 90% | 13.3d | 2002-03-20 | 2002-09-20 | 133d | 585d | finish no earlier than 2002-09-20 | T3 | 1064h | 957.6h |  |  | Rel-6 |  | Mario Pérez (Microelectrónica Española) |  |  |  |  |
| 288 | 13.1.2 | Java API Test specification (TS 43.019 Rel-5) | 340d | 2002-05-30 | 2003-09-17 |  |  | 2002-05-30 | 2003-09-17 | 340d | 327d | finish no earlier than 2003-09-17 | T3 | 2720h |  |  |  | Rel-6 |  | Mario Pérez (Microelectrónica Española) |  |  |  |  |
| 289 | 40.2 | **Rel-6 USIM toolkit enhancements** | 525d | 2000-09-25 A | 2002-09-27 | 80% | 106.64d | 2000-09-25 | 2002-09-27 | 525d | 580d |  | T3 | 14160h | 8886.88h |  |  | Rel-6 |  |  |  | Claus |  |  |
| 290 | 40.2.1 | **C SIM API** | 525d | 2000-09-25 A | 2002-09-27 | 80% | 106.64d | 2000-09-25 | 2002-09-27 | 525d | 580d |  | T3 | 9960h | 7936.88h | USAT1-API-MULTOS |  | Rel-6 | TSG |  |  |  | Ter | 2031 |
| 291 | 40.2.1.1 | Specification | 525d | 2000-09-25 A | 2002-09-27 A | 100% |  | 2000-09-25 | 2002-09-27 | 525d |  | finish no earlier than 2002-09-27 | T3 | 4200h | 4200h |  |  | Rel-6 | TSG | Neil Livingston – Aspects Software |  |  | Ter | 2032 |
| 292 | 40.2.1.2 | Test specification | 195d | 2001-01-01 A | 2001-09-28 | 25% | 146.25d | 2001-01-01 | 2001-09-28 | 195d | 840d | finish no earlier than 2001-09-28 | T3 | 1560h | 390h |  |  | Rel-6 | TSG | Neil Livingston – Aspects Software |  |  | Ter | 2033 |
| 293 | 41 | **Packet Switched Streaming Services Rel-6** | 285d? | 2002-11-18 A | 2003-12-19 | 38% | 175.45d? | 2002-11-18 | 2003-12-19 | 285d? | 260d |  | S4 | 5096h | 1958.78h | PSSrel6 |  | Rel-6 | TSG | Olle Franceschi (Ericsson) | Olle.Franceschi@emp.ericsson.se | Paolo |  |  |
| 294 | 41.1 | Stage 1 | 86d? | 2002-11-18 A | 2003-03-17 | 80% | 17.2d? | 2002-11-18 | 2003-03-17 | 86d? | 459d | finish no earlier than 2003-03-17 | S1 | 688h | 550.4h |  | 22.233 | Rel-6 | TSG |  |  |  |  |  |
| 295 | 41.2 | Stage 3 | 266d? | 2002-12-13 A | 2003-12-19 | 25% | 199.5d? | 2002-12-13 | 2003-12-19 | 266d? | 260d | start no earlier than 2002-12-13 | S4 | 2128h | 532h | PSSrel6 | 26.233, 26.234, 26.244, 26.245, 26.246 | Rel-6 | WG | Olle Franceschi (Ericsson) | Olle.Franceschi@emp.ericsson.se | Paolo |  |  |
| 296 | 42 | Network Domain Security; Authentication Framework (NDS/AF) | 481d? | 2002-02-15 A | 2003-12-19 | 10% | 432.9d? | 2002-02-15 | 2003-12-19 | 481d? | 260d | finish no earlier than 2003-12-19 | S3 | 3848h | 384.8h | SEC1-NDS-AF |  | Rel-6 | TSG | Tommi Viitanen, Nokia | tommi.viitanen@nokia.com |  |  |  |
| 297 | 43 | AMR-WB extension for high audio quality | 206d | 2002-12-13 A | 2003-09-26 | 20% | 164.8d | 2002-12-13 | 2003-09-26 | 206d | 320d | finish no earlier than 2003-09-26 | S4 | 1648h | 329.6h | AMRWB+ |  | Rel-6 | TSG | Janne Vainio (Nokia) | janne.m.vainio@nokia.com | Paolo |  |  |
| 298 | 44 | Single Antenna Receiver Interference Cancellation (SAIC) | 220.92d? | 2002-11-15 A | 2003-11-21 | 25% | 165.69d? | 2002-11-15 | 2003-11-21 | 220.92d? | 280d | finish no earlier than 2003-11-21 | GP; G1 | 3534.72h | 883.68h | SAIC |  | Rel-6 | TSG | Marc Grant, Cingular Wireless |  |  |  |  |

Notes:
- 273: az: No role for T2. SA5 awaiting progress in OMA. Rapp resigned: John Mudge (Vodafone)
- 274: az: Rapp resigned: John Mudge (Vodafone)
- 275: az: No role for T2/T (work to be done in OMA)
- 286: 8/3/2001: test spec is based on R99 core spec, so deleted from Workplan
- 294: 2nd resp SA4
- 296: WID approved SA#19. Work started after FS approved SA#18

| ID | WBS | Task | Duration | Start | Finish | Complete | Remaining | Baseline start | Baseline finish | Baseline duration | Total slack | Constraint | Resources | Work | Actual work | Text1 | Text4 | Text6 | Text7 | Text8 | Text5 | Text3 |
| --- | --- | --- | --- | --- | --- | --- | --- | --- | --- | --- | --- | --- | --- | --- | --- | --- | --- | --- | --- | --- | --- | --- |
| 299 | 45 | **Support of Conversational Services in A/Gb mode via the PS domain** | 316d? | 2003-02-07 A | 2004-04-23 | 2% | 309.98d? | 2003-02-07 | 2004-04-23 | 316d? | 170d |  | GP | 7752h | 130.53h | SCSAGB | David Bladsjö, Ericsson | Rel-6 | TSG |  |  |  |
| 300 | 45.1 | Creation of a TR | 206d? | 2003-02-07 A | 2003-11-21 | 5% | 195.7d? | 2003-02-07 | 2003-11-21 | 206d? | 280d | finish no earlier than 2003-11-21 | GP | 1648h | 82.4h | SCSAGB-TR | David Bladsjö, Ericsson | Rel-6 | TSG |  |  |  |
| 301 | 45.2 | Stage 2 | 111d? | 2003-11-21 | 2004-04-23 |  |  | 2003-11-21 | 2004-04-23 | 111d? | 170d | finish no earlier than 2004-04-23 | GP | 888h |  | SCSAGB-Stage2 | David Bladsjö, Ericsson | Rel-6 | TSG |  |  |  |
| 302 | 45.3 | Radio Channel Support | 56d? | 2004-02-06 | 2004-04-23 |  |  | 2004-02-06 | 2004-04-23 | 56d? | 170d | finish no earlier than 2004-04-23 | GP | 448h |  | SCSAGB-RCS | David Bladsjö, Ericsson | Rel-6 | TSG |  |  |  |
| 303 | 45.4 | Definition of radio resource management functionality | 56d? | 2004-02-06 | 2004-04-23 |  |  | 2004-02-06 | 2004-04-23 | 56d? | 170d | finish no earlier than 2004-04-23 | GP; G2 | 896h |  | SCSAGB-RRM | David Bladsjö, Ericsson | Rel-6 | TSG |  |  |  |
| 304 | 45.5 | PS Handover | 56d? | 2004-02-06 | 2004-04-23 |  |  | 2004-02-06 | 2004-04-23 | 56d? | 170d | finish no earlier than 2004-04-23 | GP | 448h |  | SCSAGB-PSH | David Bladsjö, Ericsson | Rel-6 | TSG |  |  |  |
| 305 | 45.6 | Modifications to FLO | 56d? | 2004-02-06 | 2004-04-23 |  |  | 2004-02-06 | 2004-04-23 | 56d? | 170d | finish no earlier than 2004-04-23 | GP; G2 | 896h |  | SCSAGB-FLO | David Bladsjö, Ericsson | Rel-6 | TSG |  |  |  |
| 306 | 46 | **Enhancement of dialled service for CAMEL** | 126d? | 2003-03-28 A | 2003-09-19 | 30% | 88.2d? | 2003-03-28 | 2003-09-19 | 126d? | 325d |  | S1 | 2016h | 604.8h | EDCAMEL | Craig Bishop, Samsung Electronics Research Institute | Rel-6 | TSG | Andrijana |  |  |
| 307 | 46.1 | Stages 2 and 3 | 126d? | 2003-03-28 A | 2003-09-19 | 30% | 88.2d? | 2003-03-28 | 2003-09-19 | 126d? | 325d | finish no earlier than 2003-09-19 | N2 | 1008h | 302.4h |  |  | Rel-6 |  |  |  |  |
| 308 | 47 | Definition of teleservice using Multimedia Broadcast/Multicast Service | 201d? | 2003-06-12 | 2004-03-18 |  |  | 2003-06-12 | 2004-03-18 | 201d? | 196d | finish no earlier than 2004-03-18 | S4 | 1608h |  | TSMBMS | Igor Curcio (Nokia) | Rel-6 | TSG |  | igor.curcio@nokia.com |  |
| 309 | 48 | Bandwith end-resource saving | 112d? | 2003-06-23 A | 2003-11-25 | 13% | 97.44d? | 2003-06-23 | 2003-11-25 | 112d? | 278d | finish no earlier than 2003-11-25 | S2 | 896h | 116.48h |  |  | Rel-6 |  |  |  | TR 23.977 |
| 310 | 49 | FS on (U)SIM Security Reuse by Peripheral Devices on Local Interfaces | 127d? | 2003-07-03 | 2003-12-26 |  |  | 2003-07-03 | 2003-12-26 | 127d? | 255d | finish no earlier than 2003-12-26 | S3 | 1016h |  |  | Raziq Yaqub, Toshiba America Research Inc. | Rel-6 | TSG | Maurice |  |  |
